# Titel: Project/Info/Proj.geg/Geav.eigensch...WTCB-Sjabloon-MSP-V20210329-NL

Schedule from MS Project, 2023-01-09 to 2024-02-24.
Sub: Kop/voettekst/legende kan verwijzen naar dit
Bedrijf: Kop/voettekst/legende kan verwijzen naar

## Calendars

- 5/7: Mon-Fri 08:00-12:00, 13:00-17:00; Sat-Sun off. Exceptions (off unless hours are given): 2021-01-01 to 2070-01-01 (1 jan - Nieuwjaar, recurring), 2021-05-01 to 2070-05-01 (1 mei - Feest van de Arbeid, recurring), 2021-07-21 to 2070-07-21 (21 jul - Nationale feestdag, recurring), 2021-08-15 to 2070-08-15 (15 aug - OLV Hemelvaart, recurring), 2021-11-01 to 2070-11-01 (1 nov - Allerheiligen, recurring), 2021-11-11 to 2070-11-11 (11 nov - Wapenstilstand, recurring), 2021-12-25 to 2070-12-25 (25 dec - Kerstmis, recurring), 2023-07-17 to 2023-08-06 (Bouwverlof 2023).

## Resources

| Resource | Group |
| --- | --- |
| TP OA AFSLUITINGEN | 02 BPV-WIN |
| TP OA WERFINRICHTING | 02 BPV-WIN |
| TP OA AFBRAAK | 03 AFBRAAK |
| TP OA GRONDWERKEN ALGEMEEN | 10 ONDERBOUW |
| TP OA BRONBEMALING | 10 ONDERBOUW |
| TP OA STUT- EN ONDERVANGINGSWERKEN | 10 ONDERBOUW |
| TP OA FUNDERING VALSE PUTTEN | 10 ONDERBOUW |
| TP OA FUNDERINGEN | 10 ONDERBOUW |
| TP OA PAALFUNDERINGEN | 10 ONDERBOUW |
| TP OA WAPENING | 20 RUWBOUW |
| TP OA BEKISTING | 20 RUWBOUW |
| TP OA BETONWERKEN | 20 RUWBOUW |
| TP OA INDUSTRIELE VLOEREN | 50 BINNENAFWERKING 1 |
| TP OA RIOLERING BINNEN | 60 TECH SA-G-VE |
| TP OA DAKWATER AFVOER | 30 DAKWERKEN |
| TP OA PREFAB-STRUCTUURELEMENTEN | 20 RUWBOUW |
| TP OA GEVELBEKLEDING PREFAB | 40 GEVELS |
| TP OA GEVELBEKLEDING ALGEMEEN | 40 GEVELS |
| TP OA METSELWERKEN ALGEMEEN | 20 RUWBOUW |
| TP OA METSELWERKEN BETONBLOKKEN | 20 RUWBOUW |
| TP OA METSELWERKEN SNELBOUW | 20 RUWBOUW |
| TP OA METSELWERKEN KALKZAND | 20 RUWBOUW |
| TP OA METSELWERKEN GEVEL | 20 RUWBOUW |
| TP OA GEVELBEKLEDING NATUURSTEEN | 40 GEVELS |
| TP OA VOEGWERK CEMENT | 20 RUWBOUW |
| TP OA GEVELBEKLEDING PLEISTERWERKEN | 40 GEVELS |
| TP OA STRUCTUUR STAAL | 20 RUWBOUW |
| TP OA DAKRANDEN EN MUURAFDEKKEN | 30 DAKWERKEN |
| TP OA DAK HELLINGSBETON | 30 DAKWERKEN |
| TP OA DAKDICHTING EN AFWERKING PLAT | 30 DAKWERKEN |
| TP OA ISOLATIE (MUREN) | 20 RUWBOUW |
| TP OA DAK KOEPELS EN LICHTSTRATEN | 30 DAKWERKEN |
| TP OA BUITENSCHRIJNWERK ALUMINIUM | 40 GEVELS |
| TP OA ELECTRICITEITSWERKEN ALGEMEEN | 70 TECH ELCTRICITEIT |
| TP OA VERWARMING | 60 TECH SA-G-VE |
| TP OA KOELCELLEN | 99 DIVERS |
| TP OA SANITAIRE CELLEN | 60 TECH SA-G-VE |
| TP OA VLOERISOLATIE | 50 BINNENAFWERKING 1 |
| TP OA CHAPPE | 50 BINNENAFWERKING 1 |
| TP OA PLEISTERWERKEN | 50 BINNENAFWERKING 1 |
| TP OA HARDE VLOEREN | 50 BINNENAFWERKING 1 |
| TP OA KUNSTSTOFVLOEREN | 50 BINNENAFWERKING 1 |
| TP OA EPOXY VLOEREN | 50 BINNENAFWERKING 1 |
| TP OA PARKETVLOEREN | 50 BINNENAFWERKING 1 |
| TP OA VERHOOGDE VLOEREN | 50 BINNENAFWERKING 1 |
| TP OA ZACHTE VLOEREN | 50 BINNENAFWERKING 1 |
| TP OA LIFTEN | 70 TECH ELCTRICITEIT |
| TP OA PLAFONDS | 50 BINNENAFWERKING 1 |
| TP OA SCHEIDINGSWANDEN | 50 BINNENAFWERKING 1 |
| TP OA SCHILDERWERKEN BINNEN | 80 AFWERKING 2 |
| TP OA VLOERMATTEN | 50 BINNENAFWERKING 1 |
| TP OA ZONNEWERING BUITEN | 40 GEVELS |
| TP OA GORDIJNEN | 99 DIVERS |
| TP OA BINNENSCHRIJNWERK ALGEMEEN | 50 BINNENAFWERKING 1 |
| TP OA KANTOORMEUBILAIR | 99 DIVERS |
| TP OA MEUBILAIR VAST | 50 BINNENAFWERKING 1 |
| TP OA MOBIELE WANDEN | 50 BINNENAFWERKING 1 |
| TP OA ROLBRUGGEN | 99 DIVERS |
| TP OA ROLLUIKEN | 40 GEVELS |
| TP OA TRIBUNEZITJES | 99 DIVERS |
| TP OA SPORTHALUITRUSTINGEN | 99 DIVERS |
| TP OA VOEGWERK PLASTISCH | 40 GEVELS |
| TP OA VEILIGHEIDSUITRUSTINGEN | 99 DIVERS |
| TP OA PICTOGRAMMEN | 99 DIVERS |
| TP OA GEVELREINIGING | 99 DIVERS |
| TP OA POORTEN | 40 GEVELS |
| TP OA WEGENISWERKEN | 90 OMGEVINGSWEKEN |
| TP OA DIVERS | 99 DIVERS |
| TP OA GROENAANLEG | 90 OMGEVINGSWEKEN |
| Overtyp de OA zo gauw gekend |  |
| Eigen personeel | 00 ALGEMEEN EIGEN PERSONEEL |
| Handlangers | 00 ALGEMEEN EIGEN PERSONEEL |
| Metsers | 00 ALGEMEEN EIGEN PERSONEEL |
| Bekisters | 00 ALGEMEEN EIGEN PERSONEEL |
| TP OA AFBRAAK ASBEST | 03 AFBRAAK |
| TP OA PROEVEN | 05 PROEVEN |
| TP OA KELDER PREFAB | 10 ONDERBOUW |
| TP OA SCHILDERWERKEN BUITEN | 80 AFWERKING 2 |
| TP OA RIOLERING-DRAINERING-PUTTEN | 10 ONDERBOUW |
| TP OA DORPELS-PLINTEN-DEKSTENEN | 20 RUWBOUW |
| TP OA HOUTSKELETBOUW | 20 RUWBOUW |
| TP OA STRUCTUUR HOUT | 20 RUWBOUW |
| TP OA STRUCTUUR BETON | 20 RUWBOUW |
| TP OA DAKWERKEN ALGEMEEN | 30 DAKWERKEN |
| TP OA DAKWERKEN HELLEND | 30 DAKWERKEN |
| TP OA DAKWERKEN PLAT | 30 DAKWERKEN |
| Werkvoorbereider | 00 ALGEMEEN EIGEN PERSONEEL |
| Werfleider / projectleider | 00 ALGEMEEN EIGEN PERSONEEL |
| Aankoopdienst | 00 ALGEMEEN EIGEN PERSONEEL |
| Opdrachtgever / Bouwheer | 01 ALGEMEEN EXTERN |
| TP OA WERFLOKALEN | 02 BPV-WIN |
| TP OA SPECIALE FUNDERINGEN | 10 ONDERBOUW |
| TP OA FUNDERING WANDEN | 10 ONDERBOUW |
| TP OA WATERDICHTING ONDERBOUW | 10 ONDERBOUW |
| TP OA DAKBEDEKKING HELLEND | 30 DAKWERKEN |
| TP OA DAKISOLATIE HELLEND | 30 DAKWERKEN |
| TP OA DAKISOLATIE PLAT | 30 DAKWERKEN |
| TP OA DAKISOLATIE ALGEMEEN | 30 DAKWERKEN |
| TP OA VENTILATIE | 60 TECH SA-G-VE |
| TP OA SANITAIR ALGEMEEN | 60 TECH SA-G-VE |
| TP OA ELECTRICITEIT | 70 TECH ELCTRICITEIT |
| TP OA BUITENSCHRIJN ALGEMEEN | 40 GEVELS |
| TP OA BUITENSCHRIJNWERK HOUT | 40 GEVELS |
| TP OA GEVELBEKLEDING HOUT | 40 GEVELS |
| TP OA BUITENTRAPPEN EN BORSTWER. | 40 GEVELS |
| TP OA TRAPPEN EN LEUNINGEN BINNEN | 50 BINNENAFWERKING 1 |
| TP OA OPKUIS | 99 DIVERS |
| Studiebureau | 01 ALGEMEEN EXTERN |
| Architect | 01 ALGEMEEN EXTERN |
| TP OA ISOLATIE ONDERBOUW | 10 ONDERBOUW |
| TP OA DAKBEDEKKING ALGEMEEN | 30 DAKWERKEN |
| TP OA DAK BALLAST PLAT | 30 DAKWERKEN |
| TP OA BUITENSCHRIJNWERK PVC | 40 GEVELS |
| TP OA BUITENSCHRIJNWERK STAAL | 40 GEVELS |
| TP OA BINNENSCHRIJNWERK DEUREN | 50 BINNENAFWERKING 1 |
| TP OA TABLETTEN EN BEKLEDINGEN | 50 BINNENAFWERKING 1 |
| TP OA GASINSTALLATIE ALGEMEEN | 60 TECH SA-G-VE |
| TP OA BRANDBESTRIJDING | 60 TECH SA-G-VE |
| TP OA BIJZONDERE INSTALLATIES | 60 TECH SA-G-VE |
| TP OA BRANDDETECTIE | 70 TECH ELCTRICITEIT |
| TP OA BEHANGWERKEN | 80 AFWERKING 2 |
| Bouwheer | 01 ALGEMEEN EXTERN |
| Aannemer | 01 ALGEMEEN EXTERN |
| Architect | 01 ALGEMEEN EXTERN |
| Studiebureau Technieken | 01 ALGEMEEN EXTERN |
| Studiebureau Stabiliteit | 01 ALGEMEEN EXTERN |
| Studiebureau's - Overig | 01 ALGEMEEN EXTERN |
| DOC | 01 ALGEMEEN EXTERN |
| D&B-team | 01 ALGEMEEN EXTERN |

## Schedule

| ID | WBS | Task | Type | Duration | Start | Finish | Predecessors | Total slack | Resources | Work | Weeknr | Verdieping | Sublot |
| --- | --- | --- | --- | --- | --- | --- | --- | --- | --- | --- | --- | --- | --- |
| 1 | 1 | **DRAAIBOEK DESIGN & BUILD** |  | 275d | 2023-01-09 | 2024-02-23 |  | 0d |  | 2200h | Wk 2 |  |  |
| 2 | 1.1 | **Handleiding / Hoe deze MsProject te gebruiken en te interpreteren** |  | 0d | 2023-01-09 | 2023-01-09 |  | 0d |  |  | Wk 2 |  |  |
| 3 | 1.1.1 | De Ms Project biedt een inhoudelijk overzicht, die als leidraad kan worden gebruikt voor een gedragen doel en een goede onderlinge afstemming & communicatie binnen het bouwteam | milestone | 0d | 2023-01-09 | 2023-01-09 |  | 0d |  |  | Wk 2 |  |  |
| 4 | 1.1.2 | 1. Taken en afhankelijkheden | milestone | 0d | 2023-01-09 | 2023-01-09 |  | 0d |  |  | Wk 2 |  |  |
| 5 | 1.1.3 | De MS Project is opgemaakt vanuit het oogpunt van het bouwteam. | milestone | 0d | 2023-01-09 | 2023-01-09 |  | 0d |  |  | Wk 2 |  |  |
| 6 | 1.1.4 | Er zijn 5 grote fases: Bouwdroom - Selectie - Wedstrijdontwerp - BAFO - Omgevingsvergunning & uitvoeringsontwerp | milestone | 0d | 2023-01-09 | 2023-01-09 |  | 0d |  |  | Wk 2 |  |  |
| 7 | 1.1.5 | Per fase zijn de verschillende taken van de verschillende partijen benoemd, gekoppeld en indicatief in een tijdsvenster weergegeven. | milestone | 0d | 2023-01-09 | 2023-01-09 |  | 0d |  |  | Wk 2 |  |  |
| 8 | 1.1.6 | Er is enkel een tijdsindicatie gegeven aan taken die binnen het Design&Build team worden uitgevoerd. Op die manier geeft de totale doorlooptijd aan hoeveel tijd het D&B team zelf nodig heeft. De tijd die de bouwheer neemt komt hier nog bij. | milestone | 0d | 2023-01-09 | 2023-01-09 |  | 0d |  |  | Wk 2 |  |  |
| 9 | 1.1.7 | Taken voor de bouwheer zijn in blauw weergegeven. De duurtijd voor deze taken staat steeds op 0. | milestone | 0d | 2023-01-09 | 2023-01-09 |  | 0d |  |  | Wk 2 |  |  |
| 10 | 1.1.8 | Globaal is de totale duurtijd van de fase representatief, de concrete planning in elke fase wordt binnen het team besproken en afgestemd. | milestone | 0d | 2023-01-09 | 2023-01-09 |  | 0d |  |  | Wk 2 |  |  |
| 11 | 1.1.9 | 2. Mijlpalen en deliverables | milestone | 0d | 2023-01-09 | 2023-01-09 |  | 0d |  |  | Wk 2 |  |  |
| 12 | 1.1.10 | De mijlpalen zijn de ankerpunten binnen een dossier: in elke fase wordt de voortgang steeds opgevolgd aan de hand van de gedefinieerde mijlpalen | milestone | 0d | 2023-01-09 | 2023-01-09 |  | 0d |  |  | Wk 2 |  |  |
| 13 | 1.1.11 | Een mijlpaal heeft slechts waarde als er ook een output, een deliverable aan is gekoppeld. In de MsProject zijn aan elke mijlpaal deliverables toegevoegd: deze laten toe te evalueren of een mijlpaal op een bepaald tijdstip is gehaald of niet | milestone | 0d | 2023-01-09 | 2023-01-09 |  | 0d |  |  | Wk 2 |  |  |
| 14 | 1.1.12 | De taken onder een mijlpaal moeten gezien worden als checklist, en dienen niet in de tijd te worden geschoven. Je kan dit opvolgen door de voortgang aan te duiden. | milestone | 0d | 2023-01-09 | 2023-01-09 |  | 0d |  |  | Wk 2 |  |  |
| 15 | 1.1.13 | In de MsProject zijn de mijlpalen en deliverables in geel weergegeven. | milestone | 0d | 2023-01-09 | 2023-01-09 |  | 0d |  |  | Wk 2 |  |  |
| 16 | 1.1.14 | In de MsProject zijn ook "Aanbevelingen" toegevoegd, documenten (checklists, templates, …) die binnen het bedrijf kunnen gemaakt worden ter ondersteuning van het proces | milestone | 0d | 2023-01-09 | 2023-01-09 |  | 0d |  |  | Wk 2 |  |  |
| 17 | 1.1.15 | 3. Gebruik van de MsProject | milestone | 0d | 2023-01-09 | 2023-01-09 |  | 0d |  |  | Wk 2 |  |  |
| 18 | 1.1.16 | Zowel taken als deliverables kunnen als "voltooid" worden aangevinkt. Maak handig gebruik van de filter om in de loop van het project enkel de onvoltooide taken weer te geven en de voortgang op te volgen | milestone | 0d | 2023-01-09 | 2023-01-09 |  | 0d |  |  | Wk 2 |  |  |
| 19 | 1.1.17 | De MsProject is opgesteld met behulp van de template die ter beschikking wordt gesteld door Buildwise. | milestone | 0d | 2023-01-09 | 2023-01-09 |  | 0d |  |  | Wk 2 |  |  |
| 20 | 1.1.18 | Deze template is te downloaden op https://leanbouwen.pxl.be/lean-tools. | milestone | 0d | 2023-01-09 | 2023-01-09 |  | 0d |  |  | Wk 2 |  |  |
| 21 | 1.1.19 | Op het YouTube kanaal van Buildwise zijn ook handige webinars te bekijken rond het werken met de MsProject template (https://www.youtube.com/playlist?list=PLMqB34dkJ6UFYhZ-OVyQ2a6AOWv-Ymw4F) | milestone | 0d | 2023-01-09 | 2023-01-09 |  | 0d |  |  | Wk 2 |  |  |
| 22 | 1.2 | Van Bouwdroom | milestone | 0d | 2023-01-09 | 2023-01-09 |  | 0d | D&B-team |  | Wk 2 | ܁% | ܁D |
| 23 | 1.3 | … |  | 275d | 2023-01-09 | 2024-02-23 | 22 | 0d | D&B-team | 2200h | Wk 2 | ܁% | ܁D |
| 24 | 1.4 | Tot Schop in de Grond | milestone | 0d | 2024-02-23 | 2024-02-23 | 23 | 0d | D&B-team |  | Wk 8 | ܁% | ܁D |

| ID | WBS | Task | Type | Duration | Start | Finish | Predecessors | Total slack | Resources | Work | Weeknr |
| --- | --- | --- | --- | --- | --- | --- | --- | --- | --- | --- | --- |
| 25 | 2 | **DESIGN&BUILD PLANNING** |  | 275d | 2023-01-09 | 2024-02-24 |  | 0d |  | 7064h | Wk 2 |
| 26 | 2.1 | **FASE 1 / BOUWDROOM** |  | 0d | 2023-01-09 | 2023-01-09 |  | 0d |  |  | Wk 2 |
| 27 | 2.1.1 | **OPDRACHT** |  | 0d | 2023-01-09 | 2023-01-09 |  | 0d |  |  | Wk 2 |
| 28 | 2.1.1.1 | Bouwdroom omschrijven | milestone | 0d | 2023-01-09 | 2023-01-09 | 22 | 0d | Bouwheer |  | Wk 2 |
| 29 | 2.1.1.2 | Pakket van Eisen vastleggen | milestone | 0d | 2023-01-09 | 2023-01-09 | 28 | 0d | Bouwheer |  | Wk 2 |
| 30 | 2.1.1.3 | Opdracht & Selectieleidraad publiceren | milestone | 0d | 2023-01-09 | 2023-01-09 | 29 | 0d | Bouwheer |  | Wk 2 |
| 31 | 2.1.1.4 | **PPS / Zorgen & Verbeteropportuniteiten naar de bouwheer** |  | 0d | 2023-01-09 | 2023-01-09 |  | 0d | DOC |  | Wk 2 |
| 32 | 2.1.1.4.1 | Is D&B de juiste keuze? (=> handleiding voor- en nadelen van elke aanbestedingswijze) | milestone | 0d | 2023-01-09 | 2023-01-09 | 30 | 0d | DOC |  | Wk 2 |
| 33 | 2.1.1.4.2 | Hebben we de juiste expertise in huis? (juridisch profiel én technisch profiel) | milestone | 0d | 2023-01-09 | 2023-01-09 | 30 | 0d | DOC |  | Wk 2 |
| 34 | 2.1.1.4.3 | Is er nood aan externe trajectbegeleider (juridisch én technisch) | milestone | 0d | 2023-01-09 | 2023-01-09 | 30 | 0d | DOC |  | Wk 2 |
| 35 | 2.1.1.4.4 | Concept in 3 lijnen | milestone | 0d | 2023-01-09 | 2023-01-09 | 30 | 0d | DOC |  | Wk 2 |
| 36 | 2.1.1.4.5 | PvE: Relatieschema's | milestone | 0d | 2023-01-09 | 2023-01-09 | 30 | 0d | DOC |  | Wk 2 |
| 37 | 2.1.1.4.6 | Technische eisen per lokaal | milestone | 0d | 2023-01-09 | 2023-01-09 | 30 | 0d | DOC |  | Wk 2 |
| 38 | 2.1.1.4.7 | Ambitiepeil (BIM - Akoestiek - HWA - LCA) | milestone | 0d | 2023-01-09 | 2023-01-09 | 30 | 0d | DOC |  | Wk 2 |
| 39 | 2.1.1.4.8 | (=> PvE is geen plan!) | milestone | 0d | 2023-01-09 | 2023-01-09 | 30 | 0d | DOC |  | Wk 2 |
| 40 | 2.1.1.4.9 | Technieker bepaalt budget ifv PvE | milestone | 0d | 2023-01-09 | 2023-01-09 | 30 | 0d | DOC |  | Wk 2 |
| 41 | 2.1.1.4.10 | Contact Stedenbouw/brandweer: haalbaarheid | milestone | 0d | 2023-01-09 | 2023-01-09 | 30 | 0d | DOC |  | Wk 2 |
| 42 | 2.1.1.4.11 | Stakeholders bepalen | milestone | 0d | 2023-01-09 | 2023-01-09 | 30 | 0d | DOC |  | Wk 2 |
| 43 | 2.1.1.4.12 | Max 3 partijen na selectiefase | milestone | 0d | 2023-01-09 | 2023-01-09 | 30 | 0d | DOC |  | Wk 2 |
| 44 | 2.1.1.4.13 | Realistisch tijdsschema bepalen en aanhouden | milestone | 0d | 2023-01-09 | 2023-01-09 | 30 | 0d | DOC |  | Wk 2 |
| 45 | 2.1.1.4.14 | Budget - grootteorde | milestone | 0d | 2023-01-09 | 2023-01-09 | 30 | 0d | DOC |  | Wk 2 |
| 46 | 2.1.1.4.15 | Correct budget ifv gewenste ambitieniveau | milestone | 0d | 2023-01-09 | 2023-01-09 | 30 | 0d | DOC |  | Wk 2 |
| 47 | 2.1.1.4.16 | Realistische biedvergoeding (1% van bouwbudget) | milestone | 0d | 2023-01-09 | 2023-01-09 | 30 | 0d | DOC |  | Wk 2 |
| 48 | 2.1.1.4.17 | (0,5% voor verliezende bieder) | milestone | 0d | 2023-01-09 | 2023-01-09 | 30 | 0d | DOC |  | Wk 2 |

| ID | WBS | Task | Type | Duration | Start | Finish | Predecessors | Total slack | Resources | Work | Weeknr |
| --- | --- | --- | --- | --- | --- | --- | --- | --- | --- | --- | --- |
| 49 | 2.1.1.5 | **PPS / Charters** |  | 0d | 2023-01-09 | 2023-01-09 |  | 0d | DOC |  | Wk 2 |
| 50 | 2.1.1.5.1 | Op de website https://leanbouwen.pxl.be/PPS-bouwheer vind je ter info en ondersteuning volgende charters: | milestone | 0d | 2023-01-09 | 2023-01-09 | 30 | 0d | DOC |  | Wk 2 |
| 51 | 2.1.1.5.2 | "Charter Samenwerking bij PPS" (2019), opgesteld door VCI, ORI en diverse Vlaamse overheidsinstellingen | milestone | 0d | 2023-01-09 | 2023-01-09 | 30 | 0d | DOC |  | Wk 2 |
| 52 | 2.1.1.5.3 | "10 aanbevelingen voor een succesvolle organisatie van architectuuropdrachten in de private en publieke sector" (2016), opgesteld door NAV | milestone | 0d | 2023-01-09 | 2023-01-09 | 30 | 0d | DOC |  | Wk 2 |
| 53 | 2.1.1.5.4 | "Overheidsaanbestedingen voor architectuuropdrachten - Position Paper" (2021), opgesteld door NAV | milestone | 0d | 2023-01-09 | 2023-01-09 | 30 | 0d | DOC |  | Wk 2 |
| 54 | 2.2 | **FASE 2 / SELECTIE** |  | 20d | 2023-01-09 | 2023-02-03 |  | 0d |  | 192h | Wk 2 |
| 55 | 2.2.1 | **MP / Selectieleidraad ontvangen** |  | 0d | 2023-01-09 | 2023-01-09 |  | 0d |  |  | Wk 2 |
| 56 | 2.2.1.1 | Selectieleidraad, met duiding van de opdracht, het verloop van de plaatsingsprocedure, de voorwaarden voor selectie en de opmaak en wijze van indiening van de aanvraag tot deelneming | milestone | 0d | 2023-01-09 | 2023-01-09 | 30 | 0d | Aannemer |  | Wk 2 |
| 57 | 2.2.2 | **KANDIDATUURSTELLING** |  | 20d | 2023-01-09 | 2023-02-03 |  | 0d |  | 192h | Wk 2 |
| 58 | 2.2.2.1 | Selectieleidraad bestuderen |  | 2d | 2023-01-09 | 2023-01-10 | 55 | 0d | Aannemer | 16h | Wk 2 |
| 59 | 2.2.2.2 | Aanbeveling / Flowchart Strategische Keuzes (partners, concept, BIM?) | milestone | 0d | 2023-01-09 | 2023-01-09 | 58SS | 0d | DOC |  | Wk 2 |
| 60 | 2.2.2.3 | Aanbeveling / Checklist kandidatuurstelling | milestone | 0d | 2023-01-09 | 2023-01-09 | 58SS | 0d | DOC |  | Wk 2 |
| 61 | 2.2.2.4 | Criteria bepalen voor teamsamenstelling |  | 2d | 2023-01-11 | 2023-01-12 | 58 | 0d | Aannemer | 16h | Wk 2 |
| 62 | 2.2.2.5 | Teamleden zoeken ifv opdracht |  | 2d | 2023-01-11 | 2023-01-12 | 61SS | 0d | Aannemer | 16h | Wk 2 |
| 63 | 2.2.2.6 | Teamleden contacteren |  | 2d | 2023-01-11 | 2023-01-12 | 61SS | 0d | Aannemer | 16h | Wk 2 |
| 64 | 2.2.2.7 | Nagaan of termijn past voor teamleden |  | 6d | 2023-01-13 | 2023-01-20 | 63 | 0d | Aannemer | 48h | Wk 2 |
| 65 | 2.2.2.8 | Team samenstellen |  | 2d | 2023-01-23 | 2023-01-24 | 64 | 0d | Aannemer | 16h | Wk 4 |
| 66 | 2.2.2.9 | Portfolio opmaken met referenties & bedrijfsdata |  | 6d | 2023-01-25 | 2023-02-01 | 65 | 0d | D&B-team | 48h | Wk 4 |
| 67 | 2.2.2.10 | Selectiedossier samenstellen (portfolio, conceptnota, dossiervisie, Gentlemen's Agreement & Charter) |  | 2d | 2023-02-02 | 2023-02-03 | 66 | 0d | Aannemer | 16h | Wk 5 |
| 68 | 2.2.2.11 | **MP / Kandidatuurstelling indienen** |  | 0d | 2023-02-03 | 2023-02-03 |  | 0d |  |  | Wk 5 |
| 69 | 2.2.2.11.1 | Keuze Architect | milestone | 0d | 2023-02-03 | 2023-02-03 | 67 | 0d | Aannemer |  | Wk 5 |
| 70 | 2.2.2.11.2 | Keuze Ingenieur Technieken | milestone | 0d | 2023-02-03 | 2023-02-03 | 67 | 0d | Aannemer |  | Wk 5 |
| 71 | 2.2.2.11.3 | Keuze Ingenieur Stabiliteit | milestone | 0d | 2023-02-03 | 2023-02-03 | 67 | 0d | Aannemer |  | Wk 5 |
| 72 | 2.2.2.11.4 | Keuze Akoestiek | milestone | 0d | 2023-02-03 | 2023-02-03 | 67 | 0d | Aannemer |  | Wk 5 |
| 73 | 2.2.2.11.5 | Keuze Tijdelijke Maatschap of niet | milestone | 0d | 2023-02-03 | 2023-02-03 | 67 | 0d | Aannemer |  | Wk 5 |
| 74 | 2.2.2.11.6 | Organigram | milestone | 0d | 2023-02-03 | 2023-02-03 | 67 | 0d | Aannemer |  | Wk 5 |
| 75 | 2.2.2.11.7 | Contractuele afspraken intern | milestone | 0d | 2023-02-03 | 2023-02-03 | 67 | 0d | Aannemer |  | Wk 5 |
| 76 | 2.2.2.11.8 | Motivatietekst ism eindredacteur | milestone | 0d | 2023-02-03 | 2023-02-03 | 67 | 0d | Aannemer |  | Wk 5 |
| 77 | 2.2.2.11.9 | Conceptnota Bouwteam | milestone | 0d | 2023-02-03 | 2023-02-03 | 67 | 0d | Aannemer |  | Wk 5 |
| 78 | 2.2.2.11.10 | ev. "Charter Samenwerking bij PPS" | milestone | 0d | 2023-02-03 | 2023-02-03 | 67 | 0d | Aannemer |  | Wk 5 |

| ID | WBS | Task | Type | Duration | Start | Finish | Predecessors | Total slack | Resources | Work | Weeknr |
| --- | --- | --- | --- | --- | --- | --- | --- | --- | --- | --- | --- |
| 79 | 2.2.3 | **BOUWHEER / SELECTIE (1 - 3 maanden?)** |  | 0d | 2023-02-03 | 2023-02-03 |  | 0d |  |  | Wk 5 |
| 80 | 2.2.3.1 | Kandidaten beoordelen | milestone | 0d | 2023-02-03 | 2023-02-03 | 68 | 0d | Bouwheer |  | Wk 5 |
| 81 | 2.2.3.2 | Kandidaten selecteren | milestone | 0d | 2023-02-03 | 2023-02-03 | 68 | 0d | Bouwheer |  | Wk 5 |
| 82 | 2.2.3.3 | Kandidaten bekendmaken | milestone | 0d | 2023-02-03 | 2023-02-03 | 68 | 0d | Bouwheer |  | Wk 5 |
| 83 | 2.2.3.4 | Vergoeding vastleggen voor verliezers | milestone | 0d | 2023-02-03 | 2023-02-03 | 68 | 0d | Bouwheer |  | Wk 5 |
| 84 | 2.2.3.5 | Gunningsleidraad opmaken (incl nodige documenten, zijnde omgevingsonderzoek, sloopopvolgingsplan, … en meer gedetailleerd eisenpakket) en versturen | milestone | 0d | 2023-02-03 | 2023-02-03 | 68 | 0d | Bouwheer |  | Wk 5 |
| 85 | 2.2.3.6 | Selectieverslag opmaken en versturen | milestone | 0d | 2023-02-03 | 2023-02-03 | 68 | 0d | Bouwheer |  | Wk 5 |
| 86 | 2.3 | **FASE 3 / WEDSTRIJDONTWERP + PRIJS** |  | 66d | 2023-02-03 | 2023-05-09 |  | 0d |  | 2552h | Wk 5 |
| 87 | 2.3.1 | **MP / Gunningsleidraad en selectieverslag ontvangen** |  | 0d | 2023-02-03 | 2023-02-03 |  | 0d |  |  | Wk 5 |
| 88 | 2.3.1.1 | Gunningsleidraad | milestone | 0d | 2023-02-03 | 2023-02-03 | 85 | 0d | Aannemer |  | Wk 5 |
| 89 | 2.3.1.2 | Selectieverslag | milestone | 0d | 2023-02-03 | 2023-02-03 | 85 | 0d | Aannemer |  | Wk 5 |
| 90 | 2.3.2 | **VOORBEREIDING** |  | 5d | 2023-02-06 | 2023-02-10 |  | 0d |  | 184h | Wk 6 |
| 91 | 2.3.2.1 | Selectieverslag bestuderen |  | 1d | 2023-02-06 | 2023-02-06 | 87 | 0d | Aannemer | 8h | Wk 6 |
| 92 | 2.3.2.2 | Gunningsleidraad verdelen onder teamleden |  | 1d | 2023-02-06 | 2023-02-06 | 87 | 0d | Aannemer | 8h | Wk 6 |
| 93 | 2.3.2.3 | Kickoff Teammeeting (live) inplannen |  | 1d | 2023-02-06 | 2023-02-06 | 87 | 0d | Aannemer | 8h | Wk 6 |
| 94 | 2.3.2.4 | Organigram team opmaken & verdelen |  | 1d | 2023-02-06 | 2023-02-06 | 87 | 0d | Aannemer | 8h | Wk 6 |
| 95 | 2.3.2.5 | Gunningsleidraad bestuderen |  | 1d | 2023-02-07 | 2023-02-07 | 94 | 0d | D&B-team | 8h | Wk 6 |
| 96 | 2.3.2.6 | Aanbeveling / Checklist beoordeling gunningsleidraad | milestone | 0d | 2023-02-07 | 2023-02-07 | 95SS | 0d | DOC |  | Wk 6 |
| 97 | 2.3.2.7 | Voorzet planning wedstrijdfase opmaken ifv mijlpalen & deliverables (wie doet wat tegen wanneer) mbv deze MsProject |  | 3d | 2023-02-08 | 2023-02-10 | 95 | 0d | Aannemer | 24h | Wk 6 |
| 98 | 2.3.2.8 | Voorzet BIM afspraken opmaken |  | 3d | 2023-02-08 | 2023-02-10 | 95 | 0d | Aannemer | 24h | Wk 6 |
| 99 | 2.3.2.9 | Aanbeveling / Standaard BIM protocol | milestone | 0d | 2023-02-08 | 2023-02-08 | 98SS | 0d | DOC |  | Wk 6 |
| 100 | 2.3.2.10 | Voorzet LEAN afspraken opmaken |  | 3d | 2023-02-08 | 2023-02-10 | 95 | 0d | Aannemer | 24h | Wk 6 |
| 101 | 2.3.2.11 | Aanbeveling / Standaard LEAN protocol | milestone | 0d | 2023-02-08 | 2023-02-08 | 100SS | 0d | DOC |  | Wk 6 |
| 102 | 2.3.2.12 | Voorzet TEAM afspraken opmaken |  | 3d | 2023-02-08 | 2023-02-10 | 95 | 0d | Aannemer | 24h | Wk 6 |
| 103 | 2.3.2.13 | Aanbeveling / Template Team Charter | milestone | 0d | 2023-02-08 | 2023-02-08 | 102SS | 0d | DOC |  | Wk 6 |
| 104 | 2.3.2.14 | Demarcatielijst opstellen voor wedstrijd (wie doet wat) |  | 3d | 2023-02-08 | 2023-02-10 | 95 | 0d | Aannemer | 24h | Wk 6 |
| 105 | 2.3.2.15 | Aanbeveling / Template Demarcatielijst | milestone | 0d | 2023-02-08 | 2023-02-08 | 104SS | 0d | DOC |  | Wk 6 |
| 106 | 2.3.2.16 | Voorzet 1ste budgetverdeling bouwbudget tussen partners verdelen onder teamleden |  | 3d | 2023-02-08 | 2023-02-10 | 95 | 0d | Aannemer | 24h | Wk 6 |

| ID | WBS | Task | Type | Duration | Start | Finish | Predecessors | Total slack | Constraint | Resources | Work | Weeknr |
| --- | --- | --- | --- | --- | --- | --- | --- | --- | --- | --- | --- | --- |
| 107 | 2.3.3 | **KICKOFF & ORGANISATIE FASE WEDSTRIJDONTWERP + PRIJS** |  | 61d | 2023-02-10 | 2023-05-09 |  | 0d |  |  | 504h | Wk 6 |
| 108 | 2.3.3.1 | **MP / Kickoff Teammeeting (live)** |  | 0d | 2023-02-10 | 2023-02-10 |  | 0d |  |  |  | Wk 6 |
| 109 | 2.3.3.1.1 | Organigram team | milestone | 0d | 2023-02-10 | 2023-02-10 | 106 | 0d |  | Aannemer |  | Wk 6 |
| 110 | 2.3.3.1.2 | Samenvatting gunningsleidraad - voorzet doel voor de klant | milestone | 0d | 2023-02-10 | 2023-02-10 | 106 | 0d |  | Aannemer |  | Wk 6 |
| 111 | 2.3.3.1.3 | Voorzet planning wedstrijdfase | milestone | 0d | 2023-02-10 | 2023-02-10 | 106 | 0d |  | Aannemer |  | Wk 6 |
| 112 | 2.3.3.1.4 | Voorzet BIM, Lean & Team afspraken | milestone | 0d | 2023-02-10 | 2023-02-10 | 106 | 0d |  | Aannemer |  | Wk 6 |
| 113 | 2.3.3.1.5 | Demarcatielijst | milestone | 0d | 2023-02-10 | 2023-02-10 | 106 | 0d |  | Aannemer |  | Wk 6 |
| 114 | 2.3.3.1.6 | Voorzet budgetverdeling | milestone | 0d | 2023-02-10 | 2023-02-10 | 106 | 0d |  | Aannemer |  | Wk 6 |
| 115 | 2.3.3.2 | Klantwaarde distilleren uit gunningsleidraad = consensus over INHOUD |  | 1d | 2023-02-13 | 2023-02-13 | 106 | 0d |  | D&B-team | 8h | Wk 7 |
| 116 | 2.3.3.3 | Aanbeveling / Checklist beschikbare info (sloopvergunning, sondering, klip-plannen, PvE voldoende gedetailleerd, …) => ifv vragen aan bouwheer bij infomoment | milestone | 0d | 2023-02-13 | 2023-02-13 | 115SS | 0d |  | DOC |  | Wk 7 |
| 117 | 2.3.3.4 | Planning op weekniveau + deliverables bepalen = consensus over TIMING |  | 1d | 2023-02-13 | 2023-02-13 | 106 | 0d |  | D&B-team | 8h | Wk 7 |
| 118 | 2.3.3.5 | BIM, Lean & Team afspraken vastleggen = consensus over SAMENWERKING |  | 1d | 2023-02-13 | 2023-02-13 | 106 | 0d |  | D&B-team | 8h | Wk 7 |
| 119 | 2.3.3.6 | 1ste budgetverdeling bouwbudget vastleggen = consensus over PRIJS |  | 1d | 2023-02-13 | 2023-02-13 | 106 | 0d |  | D&B-team | 8h | Wk 7 |
| 120 | 2.3.3.7 | Verslag Kickoff Teammeeting verdelen |  | 1d | 2023-02-14 | 2023-02-14 | 119 | 0d |  | Aannemer | 8h | Wk 7 |
| 121 | 2.3.3.8 | Aanbeveling / Template output Kickoff | milestone | 0d | 2023-02-14 | 2023-02-14 | 120SS | 0d |  | DOC |  | Wk 7 |
| 122 | 2.3.3.9 | Plaatsbezoek & 1ste vragen |  | 1d | 2023-02-16 | 2023-02-16 | 119FS+2d | 0d |  | Bouwheer | 8h | Wk 7 |
| 123 | 2.3.3.10 | Plaatsbezoek & 1ste vragen |  | 1d | 2023-02-16 | 2023-02-16 | 119FS+2d | 0d |  | D&B-team | 8h | Wk 7 |
| 124 | 2.3.3.11 | **Wekelijkse Teammeeting** |  | 56d | 2023-02-20 | 2023-05-09 | 119SS+5d | 0d |  | D&B-team | 448h | Wk 8 |
| 125 | 2.3.3.11.1 | Wekelijkse Teammeeting 1 |  | 1d | 2023-02-20 | 2023-02-20 | 119SS+5d | 0d | start no earlier than 2023-01-02 |  |  | Wk 8 |
| 126 | 2.3.3.11.2 | Wekelijkse Teammeeting 2 |  | 1d | 2023-02-27 | 2023-02-27 | 125SS+5d | 0d | start no earlier than 2023-01-09 |  |  | Wk 9 |
| 127 | 2.3.3.11.3 | Wekelijkse Teammeeting 3 |  | 1d | 2023-03-06 | 2023-03-06 | 126SS+5d | 0d | start no earlier than 2023-01-16 |  |  | Wk 10 |
| 128 | 2.3.3.11.4 | Wekelijkse Teammeeting 4 |  | 1d | 2023-03-13 | 2023-03-13 | 127SS+5d | 0d | start no earlier than 2023-01-23 |  |  | Wk 11 |
| 129 | 2.3.3.11.5 | Wekelijkse Teammeeting 5 |  | 1d | 2023-03-20 | 2023-03-20 | 128SS+5d | 0d | start no earlier than 2023-01-30 |  |  | Wk 12 |
| 130 | 2.3.3.11.6 | Wekelijkse Teammeeting 6 |  | 1d | 2023-03-27 | 2023-03-27 | 129SS+5d | 0d | start no earlier than 2023-02-06 |  |  | Wk 13 |
| 131 | 2.3.3.11.7 | Wekelijkse Teammeeting 7 |  | 1d | 2023-04-03 | 2023-04-03 | 130SS+5d | 0d | start no earlier than 2023-02-13 |  |  | Wk 14 |
| 132 | 2.3.3.11.8 | Wekelijkse Teammeeting 8 |  | 1d | 2023-04-10 | 2023-04-10 | 131SS+5d | 0d | start no earlier than 2023-02-20 |  |  | Wk 15 |
| 133 | 2.3.3.11.9 | Wekelijkse Teammeeting 9 |  | 1d | 2023-04-17 | 2023-04-17 | 132SS+5d | 0d | start no earlier than 2023-02-27 |  |  | Wk 16 |
| 134 | 2.3.3.11.10 | Wekelijkse Teammeeting 10 |  | 1d | 2023-04-24 | 2023-04-24 | 133SS+5d | 0d | start no earlier than 2023-03-06 |  |  | Wk 17 |
| 135 | 2.3.3.11.11 | Wekelijkse Teammeeting 11 |  | 1d | 2023-05-02 | 2023-05-02 | 134SS+5d | 0d | start no earlier than 2023-03-13 |  |  | Wk 18 |
| 136 | 2.3.3.11.12 | Wekelijkse Teammeeting 12 |  | 1d | 2023-05-09 | 2023-05-09 | 135SS+5d | 0d | start no earlier than 2023-03-20 |  |  | Wk 19 |
| 137 | 2.3.3.12 | Aanbeveling / Template agenda & verslag (beslissingen, to do's) | milestone | 0d | 2023-02-20 | 2023-02-20 | 124SS | 0d |  | DOC |  | Wk 8 |

| ID | WBS | Task | Type | Duration | Start | Finish | Predecessors | Total slack | Resources | Work | Weeknr |
| --- | --- | --- | --- | --- | --- | --- | --- | --- | --- | --- | --- |
| 138 | 2.3.4 | **SCHETSONTWERP** |  | 20d | 2023-02-14 | 2023-03-13 |  | 0d |  | 576h | Wk 7 |
| 139 | 2.3.4.1 | Conceptuele uitgangspunten architectuur uittekenen |  | 2d | 2023-02-14 | 2023-02-15 | 119 | 0d | Architect | 16h | Wk 7 |
| 140 | 2.3.4.2 | Volumestudie: stedenbouwkundige inpassing gebouw in omgeving uitwerken |  | 3d | 2023-02-16 | 2023-02-20 | 139 | 0d | Architect | 24h | Wk 7 |
| 141 | 2.3.4.3 | Conceptuele uitgangspunten technieken opmaken |  | 4d | 2023-02-14 | 2023-02-17 | 119 | 0d | Studiebureau Technieken | 32h | Wk 7 |
| 142 | 2.3.4.4 | Vooradvies geven ivm Technieken |  | 1d | 2023-02-20 | 2023-02-20 | 141 | 0d | Studiebureau Technieken | 8h | Wk 8 |
| 143 | 2.3.4.5 | Conceptuele uitgangspunten stabiliteit opmaken |  | 4d | 2023-02-14 | 2023-02-17 | 119 | 0d | Studiebureau Stabiliteit | 32h | Wk 7 |
| 144 | 2.3.4.6 | Vooradvies geven ivm vloeropbouw, fundering, bouwput, bemaling, .. |  | 1d | 2023-02-20 | 2023-02-20 | 143 | 0d | Studiebureau Stabiliteit | 8h | Wk 8 |
| 145 | 2.3.4.7 | Vooradvies EPB-eisen bepalen voor bouwproject obv PvE |  | 4d | 2023-02-14 | 2023-02-17 | 119 | 0d | Studiebureau's - Overig | 32h | Wk 7 |
| 146 | 2.3.4.8 | Ambitieniveau duurzaamheid vastleggen |  | 1d | 2023-02-20 | 2023-02-20 | 145 | 0d | Studiebureau's - Overig | 8h | Wk 8 |
| 147 | 2.3.4.9 | Vooradvies EPB-eisen geven voor bouwproject obv PvE |  | 1d | 2023-02-20 | 2023-02-20 | 145 | 0d | Studiebureau's - Overig | 8h | Wk 8 |
| 148 | 2.3.4.10 | Aftoetsen raming bouwkost (compactheid, gevel/ramen, technieken, …) |  | 1d | 2023-02-20 | 2023-02-20 | 141 | 0d | Aannemer | 8h | Wk 8 |
| 149 | 2.3.4.11 | Aftoetsing ontwerp- en uitvoeringstijd (hogere prijs tov kortere uitvoeringstijd) |  | 1d | 2023-02-20 | 2023-02-20 | 141 | 0d | Aannemer | 8h | Wk 8 |
| 150 | 2.3.4.12 | Funcionele & ruimtelijke indeling gebouw vastleggen |  | 5d | 2023-02-21 | 2023-02-27 | 140 | 0d | Architect | 40h | Wk 8 |
| 151 | 2.3.4.13 | Aanwezige nutsvoorzieningen onderzoeken |  | 5d | 2023-02-21 | 2023-02-27 | 142 | 0d | Studiebureau Technieken | 40h | Wk 8 |
| 152 | 2.3.4.14 | Vooradvies geven ivm brandveiligheid |  | 1d | 2023-02-27 | 2023-02-27 | 147FS+4d | 0d | Studiebureau's - Overig | 8h | Wk 9 |
| 153 | 2.3.4.15 | Vooradvies geven ivm akoestiek |  | 1d | 2023-02-27 | 2023-02-27 | 147FS+4d | 0d | Studiebureau's - Overig | 8h | Wk 9 |
| 154 | 2.3.4.16 | Integreren & coördineren van adviezen/schetsen studiebureau's in conceptvoorstel |  | 5d | 2023-02-28 | 2023-03-06 | 150 | 0d | Architect | 40h | Wk 9 |
| 155 | 2.3.4.17 | **MP / Concept goedkeuren** |  | 0d | 2023-03-06 | 2023-03-06 |  | 0d |  |  | Wk 10 |
| 156 | 2.3.4.17.1 | Moet ambitiepeil van OpdrachtGever (OG) perfect weergeven | milestone | 0d | 2023-03-06 | 2023-03-06 | 154 | 0d | Architect |  | Wk 10 |
| 157 | 2.3.4.17.2 | Moet duidelijk zijn ("in 3 lijnen") | milestone | 0d | 2023-03-06 | 2023-03-06 | 154 | 0d | Architect |  | Wk 10 |
| 158 | 2.3.4.17.3 | Is een cyclus-proces | milestone | 0d | 2023-03-06 | 2023-03-06 | 154 | 0d | Architect |  | Wk 10 |
| 159 | 2.3.4.17.4 | Budget per partner afspreken | milestone | 0d | 2023-03-06 | 2023-03-06 | 154 | 0d | Architect |  | Wk 10 |
| 160 | 2.3.4.17.5 | Strategische ontwerpkeuzes maken (organigram) | milestone | 0d | 2023-03-06 | 2023-03-06 | 154 | 0d | Architect |  | Wk 10 |
| 161 | 2.3.4.17.6 | Financiële check door aannemer | milestone | 0d | 2023-03-06 | 2023-03-06 | 154 | 0d | Architect |  | Wk 10 |
| 162 | 2.3.4.17.7 | Vraag aan Bouwheer: Individueel aftoetsmoment | milestone | 0d | 2023-03-06 | 2023-03-06 | 154 | 0d | Architect |  | Wk 10 |
| 163 | 2.3.4.17.8 | Vraag aan Bouwheer: Hier reeds doorselectie bepalen (bvb 5 > 3) OBV CONCEPT | milestone | 0d | 2023-03-06 | 2023-03-06 | 154 | 0d | Architect |  | Wk 10 |
| 164 | 2.3.4.18 | Ontwerpen architectonische verschijningsvorm gebouwen - high level |  | 4d | 2023-03-07 | 2023-03-10 | 155 | 0d | Architect | 32h | Wk 10 |
| 165 | 2.3.4.19 | Schetsontwerp technieken opmaken |  | 4d | 2023-03-07 | 2023-03-10 | 155 | 0d | Studiebureau Technieken | 32h | Wk 10 |
| 166 | 2.3.4.20 | Schetsontwerp stabiliteit opmaken |  | 4d | 2023-03-07 | 2023-03-10 | 155 | 0d | Studiebureau Stabiliteit | 32h | Wk 10 |
| 167 | 2.3.4.21 | Simulatie duurzaamheidsscore schetsontwerp maken |  | 4d | 2023-03-07 | 2023-03-10 | 155 | 0d | Studiebureau's - Overig | 32h | Wk 10 |
| 168 | 2.3.4.22 | Haalbaarheidsstudie hernieuwbare energie opmaken |  | 4d | 2023-03-07 | 2023-03-10 | 155 | 0d | Studiebureau's - Overig | 32h | Wk 10 |
| 169 | 2.3.4.23 | Wettelijke eisen EPB nagaan & aftoetsen |  | 4d | 2023-03-07 | 2023-03-10 | 155 | 0d | Studiebureau's - Overig | 32h | Wk 10 |
| 170 | 2.3.4.24 | Brandbestrijdingsdiensten contacteren & bevragen |  | 1d | 2023-03-07 | 2023-03-07 | 155 | 0d | Studiebureau's - Overig | 8h | Wk 10 |
| 171 | 2.3.4.25 | Ontwerp brandveiligheid opmaken |  | 3d | 2023-03-08 | 2023-03-10 | 170 | 0d | Studiebureau's - Overig | 24h | Wk 10 |
| 172 | 2.3.4.26 | Ruwe raming - kwantitatieve analyse schetsontwerp uitvoeren (m²) |  | 1d | 2023-03-13 | 2023-03-13 | 165 | 0d | D&B-team | 8h | Wk 11 |
| 173 | 2.3.4.27 | Ruwe raming - financiële analyse schetsontwerp uitvoeren |  | 1d | 2023-03-13 | 2023-03-13 | 165 | 0d | D&B-team | 8h | Wk 11 |
| 174 | 2.3.4.28 | Aftoetsen schetsontwerp aan bestek & regelgeving |  | 1d | 2023-03-13 | 2023-03-13 | 165 | 0d | D&B-team | 8h | Wk 11 |
| 175 | 2.3.4.29 | Aftoetsen toegankelijkheid gebouw |  | 1d | 2023-03-13 | 2023-03-13 | 165 | 0d | D&B-team | 8h | Wk 11 |

| ID | WBS | Task | Type | Duration | Start | Finish | Predecessors | Total slack | Resources | Work | Weeknr |
| --- | --- | --- | --- | --- | --- | --- | --- | --- | --- | --- | --- |
| 176 | 2.3.4.30 | **MP / Schetsontwerp goedkeuren** |  | 0d | 2023-03-13 | 2023-03-13 |  | 0d |  |  | Wk 11 |
| 177 | 2.3.4.30.1 | Bouwconcept vastleggen (prefab of in situ, technieken, …) | milestone | 0d | 2023-03-13 | 2023-03-13 | 175 | 0d | D&B-team |  | Wk 11 |
| 178 | 2.3.5 | **VOORONTWERP** |  | 20d | 2023-03-14 | 2023-04-10 |  | 0d |  | 936h | Wk 11 |
| 179 | 2.3.5.1 | Vastleggen definitieve stedenbouwkundige inpassing gebouwen |  | 4d | 2023-03-14 | 2023-03-17 | 176 | 0d | Architect | 32h | Wk 11 |
| 180 | 2.3.5.2 | Vastleggen functionele & ruimtelijke indeling gebouwen |  | 3d | 2023-03-20 | 2023-03-22 | 179 | 0d | Architect | 24h | Wk 12 |
| 181 | 2.3.5.3 | Vastleggen architectonische verschijningsvorm gebouwen |  | 2d | 2023-03-23 | 2023-03-24 | 180 | 0d | Architect | 16h | Wk 12 |
| 182 | 2.3.5.4 | Ontwerpen globale materialisatie gebouwen |  | 5d | 2023-03-27 | 2023-03-31 | 181 | 0d | Architect | 40h | Wk 13 |
| 183 | 2.3.5.5 | Integreren & coördineren van adviezen/ontwerpen studiebureau's (technieken, structuur, brand, …) |  | 5d | 2023-04-03 | 2023-04-07 | 182 | 0d | Architect | 40h | Wk 14 |
| 184 | 2.3.5.6 | Opmaken voorontwerp technieken: predimensionering & schachten |  | 5d | 2023-03-14 | 2023-03-20 | 176 | 0d | Studiebureau Technieken | 40h | Wk 11 |
| 185 | 2.3.5.7 | Opmaken voorontwerp technieken: basisplannen & schema's |  | 14d | 2023-03-21 | 2023-04-07 | 184 | 0d | Studiebureau Technieken | 112h | Wk 12 |
| 186 | 2.3.5.8 | Opmaken voorontwerp stabiliteit |  | 19d | 2023-03-14 | 2023-04-07 | 176 | 0d | Studiebureau Stabiliteit | 152h | Wk 11 |
| 187 | 2.3.5.9 | Uitvoeren simulatie duurzaamheidsscore voorontwerp |  | 19d | 2023-03-14 | 2023-04-07 | 176 | 0d | Studiebureau's - Overig | 152h | Wk 11 |
| 188 | 2.3.5.10 | Opmaken ontwerp brandveiligheid |  | 19d | 2023-03-14 | 2023-04-07 | 176 | 0d | Studiebureau's - Overig | 152h | Wk 11 |
| 189 | 2.3.5.11 | Bepalen taken veiligheidscoördinatie project (wettelijke opdracht) |  | 14d | 2023-03-14 | 2023-03-31 | 176 | 0d | Aannemer | 112h | Wk 11 |
| 190 | 2.3.5.12 | Afstemmen takenpakket veiligheid met veiligheidscoördinator |  | 5d | 2023-04-03 | 2023-04-07 | 189 | 0d | Aannemer | 40h | Wk 14 |
| 191 | 2.3.5.13 | Aftoetsen voorontwerp aan bestek & regelgeving |  | 1d | 2023-04-10 | 2023-04-10 | 183 | 0d | D&B-team | 8h | Wk 15 |
| 192 | 2.3.5.14 | Kwantitatieve analyse voorontwerp opmaken |  | 1d | 2023-04-10 | 2023-04-10 | 183 | 0d | D&B-team | 8h | Wk 15 |
| 193 | 2.3.5.15 | Financiële analyse voorontwerp opmaken |  | 1d | 2023-04-10 | 2023-04-10 | 183 | 0d | D&B-team | 8h | Wk 15 |
| 194 | 2.3.5.16 | **MP / Voorontwerp goedkeuren en tender opstarten = DESIGN FREEZE** |  | 0d | 2023-04-10 | 2023-04-10 |  | 0d |  |  | Wk 15 |
| 195 | 2.3.5.16.1 | Grondplannen | milestone | 0d | 2023-04-10 | 2023-04-10 | 193 | 0d | D&B-team |  | Wk 15 |
| 196 | 2.3.5.16.2 | Snedes | milestone | 0d | 2023-04-10 | 2023-04-10 | 193 | 0d | D&B-team |  | Wk 15 |
| 197 | 2.3.5.16.3 | Gevels | milestone | 0d | 2023-04-10 | 2023-04-10 | 193 | 0d | D&B-team |  | Wk 15 |
| 198 | 2.3.5.16.4 | Plafondplannen | milestone | 0d | 2023-04-10 | 2023-04-10 | 193 | 0d | D&B-team |  | Wk 15 |
| 199 | 2.3.5.16.5 | (Vloerplannen) | milestone | 0d | 2023-04-10 | 2023-04-10 | 193 | 0d | D&B-team |  | Wk 15 |
| 200 | 2.3.5.16.6 | (Deurenborderel) | milestone | 0d | 2023-04-10 | 2023-04-10 | 193 | 0d | D&B-team |  | Wk 15 |
| 201 | 2.3.5.16.7 | Stiftplannen Ingenieur Stabiliteit | milestone | 0d | 2023-04-10 | 2023-04-10 | 193 | 0d | D&B-team |  | Wk 15 |
| 202 | 2.3.5.16.8 | Plannen Ingenieur Technieken | milestone | 0d | 2023-04-10 | 2023-04-10 | 193 | 0d | D&B-team |  | Wk 15 |
| 203 | 2.3.5.16.9 | Compartimenteringsplannen Brand | milestone | 0d | 2023-04-10 | 2023-04-10 | 193 | 0d | D&B-team |  | Wk 15 |
| 204 | 2.3.5.16.10 | EPB-nota | milestone | 0d | 2023-04-10 | 2023-04-10 | 193 | 0d | D&B-team |  | Wk 15 |
| 205 | 2.3.5.16.11 | Nota Akoestiek (akoestische eisen) | milestone | 0d | 2023-04-10 | 2023-04-10 | 193 | 0d | D&B-team |  | Wk 15 |
| 206 | 2.3.5.16.12 | Nota aandachtspunten Veiligheid (in uitvoeringsfase en in gebruiksfase) | milestone | 0d | 2023-04-10 | 2023-04-10 | 193 | 0d | D&B-team |  | Wk 15 |
| 207 | 2.3.5.16.13 | Oppervlaktentabel (bruto-netto) | milestone | 0d | 2023-04-10 | 2023-04-10 | 193 | 0d | D&B-team |  | Wk 15 |
| 208 | 2.3.5.16.14 | Materialenlijst | milestone | 0d | 2023-04-10 | 2023-04-10 | 193 | 0d | D&B-team |  | Wk 15 |
| 209 | 2.3.5.16.15 | Aftoetsen budget | milestone | 0d | 2023-04-10 | 2023-04-10 | 193 | 0d | D&B-team |  | Wk 15 |
| 210 | 2.3.5.16.16 | Aftoetsen bouwheer | milestone | 0d | 2023-04-10 | 2023-04-10 | 193 | 0d | D&B-team |  | Wk 15 |
| 211 | 2.3.5.16.17 | Goedz VC ontwerp | milestone | 0d | 2023-04-10 | 2023-04-10 | 193 | 0d | D&B-team |  | Wk 15 |

| ID | WBS | Task | Type | Duration | Start | Finish | Predecessors | Total slack | Resources | Work | Weeknr |
| --- | --- | --- | --- | --- | --- | --- | --- | --- | --- | --- | --- |
| 212 | 2.3.6 | **PRIJSZETTING & DOSSIER** |  | 20d | 2023-04-11 | 2023-05-09 |  | 0d |  | 352h | Wk 15 |
| 213 | 2.3.6.1 | Ontwerpen meubilair |  | 7d | 2023-04-11 | 2023-04-19 | 194 | 0d | Architect | 56h | Wk 15 |
| 214 | 2.3.6.2 | Ontwerpen omgeving |  | 3d | 2023-04-20 | 2023-04-24 | 213 | 0d | Architect | 24h | Wk 16 |
| 215 | 2.3.6.3 | Visualisaties & film |  | 1d | 2023-04-25 | 2023-04-25 | 214 | 0d | Architect | 8h | Wk 17 |
| 216 | 2.3.6.4 | Nota Stedenbouwk, arch, funct-ruimtelijke vertaling PVE - functionaliteit |  | 1d | 2023-04-11 | 2023-04-11 | 194 | 0d | Aannemer | 8h | Wk 15 |
| 217 | 2.3.6.5 | Nota Stedenbouwk, arch, funct-ruimtelijke vertaling PVE - gebruik |  | 1d | 2023-04-12 | 2023-04-12 | 216 | 0d | Aannemer | 8h | Wk 15 |
| 218 | 2.3.6.6 | Nota Technische vertaling eisen - functionaliteit |  | 1d | 2023-04-13 | 2023-04-13 | 217 | 0d | Aannemer | 8h | Wk 15 |
| 219 | 2.3.6.7 | Nota Technische vertaling eisen - gebruik |  | 1d | 2023-04-14 | 2023-04-14 | 218 | 0d | Aannemer | 8h | Wk 15 |
| 220 | 2.3.6.8 | Nota Technische vertaling eisen - veiligheid |  | 1d | 2023-04-17 | 2023-04-17 | 219 | 0d | Aannemer | 8h | Wk 16 |
| 221 | 2.3.6.9 | Nota Plan van aanpak: werking D&B-team |  | 1d | 2023-04-18 | 2023-04-18 | 220 | 0d | Aannemer | 8h | Wk 16 |
| 222 | 2.3.6.10 | Nota Plan van aanpak: ontwerpmethodiek en projectorganisatie |  | 1d | 2023-04-19 | 2023-04-19 | 221 | 0d | Aannemer | 8h | Wk 16 |
| 223 | 2.3.6.11 | Nota Plan van aanpak: werforganisatie |  | 1d | 2023-04-20 | 2023-04-20 | 222 | 0d | Aannemer | 8h | Wk 16 |
| 224 | 2.3.6.12 | Nota Plan van aanpak: veiligheid |  | 1d | 2023-04-21 | 2023-04-21 | 223 | 0d | Aannemer | 8h | Wk 16 |
| 225 | 2.3.6.13 | Nota Plan van aanpak: budgetbeheersing en -opvolging |  | 1d | 2023-04-24 | 2023-04-24 | 224 | 0d | Aannemer | 8h | Wk 17 |
| 226 | 2.3.6.14 | Nota Plan van aanpak: kwaliteitsbeheersing en -opvolging |  | 1d | 2023-04-25 | 2023-04-25 | 225 | 0d | Aannemer | 8h | Wk 17 |
| 227 | 2.3.6.15 | Nota Plan van aanpak: informatie- en communicatiebeheer |  | 1d | 2023-04-26 | 2023-04-26 | 226 | 0d | Aannemer | 8h | Wk 17 |
| 228 | 2.3.6.16 | Termijn |  | 1d | 2023-04-27 | 2023-04-27 | 227 | 0d | Aannemer | 8h | Wk 17 |
| 229 | 2.3.6.17 | Prijsaanvragen & calculatie |  | 8d | 2023-04-11 | 2023-04-20 | 194 | 0d | Aannemer | 64h | Wk 15 |
| 230 | 2.3.6.18 | Meetstaat & Prijs |  | 5d | 2023-04-21 | 2023-04-27 | 229 | 0d | Aannemer | 40h | Wk 16 |
| 231 | 2.3.6.19 | Kansen & Risico's (1 week voor indienen) |  | 1d | 2023-04-28 | 2023-04-28 | 230 | 0d | Aannemer | 8h | Wk 17 |
| 232 | 2.3.6.20 | Aanbeveling / Template Kansen & Risico's | milestone | 0d | 2023-04-28 | 2023-04-28 | 231SS | 0d | DOC |  | Wk 17 |
| 233 | 2.3.6.21 | Interne meeting - laatste opportuniteiten |  | 1d | 2023-05-02 | 2023-05-02 | 231 | 0d | D&B-team | 8h | Wk 18 |
| 234 | 2.3.6.22 | Laatste opportuniteiten verwerken en afwerken dossier |  | 5d | 2023-05-03 | 2023-05-09 | 233 | 0d | D&B-team | 40h | Wk 18 |
| 235 | 2.3.6.23 | **MP /Indienen wedstrijddossier** |  | 0d | 2023-05-09 | 2023-05-09 |  | 0d |  |  | Wk 19 |
| 236 | 2.3.6.23.1 | Output Voorontwerp (plannen & nota's) | milestone | 0d | 2023-05-09 | 2023-05-09 | 234 | 0d | Aannemer |  | Wk 19 |
| 237 | 2.3.6.23.2 | Conceptnota Architect | milestone | 0d | 2023-05-09 | 2023-05-09 | 234 | 0d | Aannemer |  | Wk 19 |
| 238 | 2.3.6.23.3 | Conceptnota Ingenieur Technieken | milestone | 0d | 2023-05-09 | 2023-05-09 | 234 | 0d | Aannemer |  | Wk 19 |
| 239 | 2.3.6.23.4 | Conceptnota Ingenieur Stabiliteit | milestone | 0d | 2023-05-09 | 2023-05-09 | 234 | 0d | Aannemer |  | Wk 19 |
| 240 | 2.3.6.23.5 | Conceptnota overig | milestone | 0d | 2023-05-09 | 2023-05-09 | 234 | 0d | Aannemer |  | Wk 19 |
| 241 | 2.3.6.23.6 | Plan van Aanpak | milestone | 0d | 2023-05-09 | 2023-05-09 | 234 | 0d | Aannemer |  | Wk 19 |
| 242 | 2.3.6.23.7 | Werfinrichtingsplan | milestone | 0d | 2023-05-09 | 2023-05-09 | 234 | 0d | Aannemer |  | Wk 19 |
| 243 | 2.3.6.23.8 | Planning | milestone | 0d | 2023-05-09 | 2023-05-09 | 234 | 0d | Aannemer |  | Wk 19 |
| 244 | 2.3.6.23.9 | Prijs | milestone | 0d | 2023-05-09 | 2023-05-09 | 234 | 0d | Aannemer |  | Wk 19 |
| 245 | 2.3.6.23.10 | 3D-beelden | milestone | 0d | 2023-05-09 | 2023-05-09 | 234 | 0d | Aannemer |  | Wk 19 |
| 246 | 2.3.6.23.11 | Verslag brandweer - advies | milestone | 0d | 2023-05-09 | 2023-05-09 | 234 | 0d | Aannemer |  | Wk 19 |
| 247 | 2.3.6.23.12 | Verslag stedenbouw - advies & adviesorganen | milestone | 0d | 2023-05-09 | 2023-05-09 | 234 | 0d | Aannemer |  | Wk 19 |
| 248 | 2.3.6.23.13 | Technische Fiches | milestone | 0d | 2023-05-09 | 2023-05-09 | 234 | 0d | Aannemer |  | Wk 19 |
| 249 | 2.3.6.23.14 | Administratieve documenten | milestone | 0d | 2023-05-09 | 2023-05-09 | 234 | 0d | Aannemer |  | Wk 19 |

| ID | WBS | Task | Type | Duration | Start | Finish | Predecessors | Total slack | Constraint | Resources | Work | Weeknr |
| --- | --- | --- | --- | --- | --- | --- | --- | --- | --- | --- | --- | --- |
| 250 | 2.3.7 | **BOUWHEER / KEUZE BOUWTEAM** |  | 0d | 2023-05-09 | 2023-05-09 |  | 0d |  |  |  | Wk 19 |
| 251 | 2.3.7.1 | Ontvangen offertes, analyse & vergelijking | milestone | 0d | 2023-05-09 | 2023-05-09 | 235 | 0d |  | Bouwheer |  | Wk 19 |
| 252 | 2.3.7.2 | Risico-allocatie | milestone | 0d | 2023-05-09 | 2023-05-09 | 235 | 0d |  | Bouwheer |  | Wk 19 |
| 253 | 2.3.7.3 | Tussentijdse meeting | milestone | 0d | 2023-05-09 | 2023-05-09 | 235 | 0d |  | Bouwheer |  | Wk 19 |
| 254 | 2.3.7.4 | Tussentijdse meeting | milestone | 0d | 2023-05-09 | 2023-05-09 | 235 | 0d |  | D&B-team |  | Wk 19 |
| 255 | 2.3.7.5 | Kiezen van het bouwteam | milestone | 0d | 2023-05-09 | 2023-05-09 | 235 | 0d |  | Bouwheer |  | Wk 19 |
| 256 | 2.4 | **FASE 4 / BAFO** |  | 36d | 2023-05-09 | 2023-06-28 |  | 0d |  |  | 696h | Wk 19 |
| 257 | 2.4.1 | **MP / Definitief bouwteam** |  | 0d | 2023-05-09 | 2023-05-09 |  | 0d |  |  |  | Wk 19 |
| 258 | 2.4.1.1 | Gunningsverslag | milestone | 0d | 2023-05-09 | 2023-05-09 | 250 | 0d |  | Aannemer |  | Wk 19 |
| 259 | 2.4.2 | **KICKOFF & ORGANISATIE FASE BAFO** |  | 36d | 2023-05-09 | 2023-06-28 |  | 0d |  |  | 256h | Wk 19 |
| 260 | 2.4.2.1 | **MP / Kickoff Teammeeting** |  | 0d | 2023-05-09 | 2023-05-09 |  | 0d |  |  |  | Wk 19 |
| 261 | 2.4.2.1.1 | Samenvatting gunningsverslag | milestone | 0d | 2023-05-09 | 2023-05-09 | 257 | 0d |  | Aannemer |  | Wk 19 |
| 262 | 2.4.2.1.2 | Voorzet planning BAFO-fase | milestone | 0d | 2023-05-09 | 2023-05-09 | 257 | 0d |  | Aannemer |  | Wk 19 |
| 263 | 2.4.2.1.3 | Voorzet BIM, Lean & Team afspraken | milestone | 0d | 2023-05-09 | 2023-05-09 | 257 | 0d |  | Aannemer |  | Wk 19 |
| 264 | 2.4.2.2 | Kickoff |  | 1d | 2023-05-10 | 2023-05-10 | 260 | 0d |  | D&B-team | 8h | Wk 19 |
| 265 | 2.4.2.3 | **Wekelijkse Teammeeting** |  | 31d | 2023-05-17 | 2023-06-28 | 264SS+5d | 0d |  | D&B-team | 248h | Wk 20 |
| 266 | 2.4.2.3.1 | Wekelijkse Teammeeting 1 |  | 1d | 2023-05-17 | 2023-05-17 | 264SS+5d | 0d | start no earlier than 2023-01-02 |  |  | Wk 20 |
| 267 | 2.4.2.3.2 | Wekelijkse Teammeeting 2 |  | 1d | 2023-05-24 | 2023-05-24 | 266SS+5d | 0d | start no earlier than 2023-01-09 |  |  | Wk 21 |
| 268 | 2.4.2.3.3 | Wekelijkse Teammeeting 3 |  | 1d | 2023-05-31 | 2023-05-31 | 267SS+5d | 0d | start no earlier than 2023-01-16 |  |  | Wk 22 |
| 269 | 2.4.2.3.4 | Wekelijkse Teammeeting 4 |  | 1d | 2023-06-07 | 2023-06-07 | 268SS+5d | 0d | start no earlier than 2023-01-23 |  |  | Wk 23 |
| 270 | 2.4.2.3.5 | Wekelijkse Teammeeting 5 |  | 1d | 2023-06-14 | 2023-06-14 | 269SS+5d | 0d | start no earlier than 2023-01-30 |  |  | Wk 24 |
| 271 | 2.4.2.3.6 | Wekelijkse Teammeeting 6 |  | 1d | 2023-06-21 | 2023-06-21 | 270SS+5d | 0d | start no earlier than 2023-02-06 |  |  | Wk 25 |
| 272 | 2.4.2.3.7 | Wekelijkse Teammeeting 7 |  | 1d | 2023-06-28 | 2023-06-28 | 271SS+5d | 0d | start no earlier than 2023-02-13 |  |  | Wk 26 |
| 273 | 2.4.3 | **BAFO** |  | 35d | 2023-05-10 | 2023-06-27 |  | 0d |  |  | 440h | Wk 19 |
| 274 | 2.4.3.1 | Uitwerken aanpassingen PvE |  | 5d | 2023-05-10 | 2023-05-16 | 257 | 0d |  | Bouwheer | 40h | Wk 19 |
| 275 | 2.4.3.2 | Onderhandelen & zoeken naar optimalisaties - 3 loops |  | 15d | 2023-05-17 | 2023-06-06 | 274 | 0d |  | Bouwheer | 120h | Wk 20 |
| 276 | 2.4.3.3 | Onderhandelen & zoeken naar optimalisaties - 3 loops |  | 15d | 2023-05-17 | 2023-06-06 | 274 | 0d |  | D&B-team | 120h | Wk 20 |
| 277 | 2.4.3.4 | Uitwerken aanpassingen ifv BAFO & onderhandelingen |  | 5d | 2023-06-07 | 2023-06-13 | 276 | 0d |  | D&B-team | 40h | Wk 23 |
| 278 | 2.4.3.5 | Opmaken specificaties & technische details |  | 5d | 2023-06-14 | 2023-06-20 | 277 | 0d |  | D&B-team | 40h | Wk 24 |
| 279 | 2.4.3.6 | Uitvoeringstermijn & planning bijstellen |  | 5d | 2023-06-14 | 2023-06-20 | 277 | 0d |  | Aannemer | 40h | Wk 24 |
| 280 | 2.4.3.7 | Forfaitaire BAFO berekenen |  | 5d | 2023-06-21 | 2023-06-27 | 279 | 0d |  | Aannemer | 40h | Wk 25 |

| ID | WBS | Task | Type | Duration | Start | Finish | Predecessors | Total slack | Constraint | Resources | Work | Weeknr |
| --- | --- | --- | --- | --- | --- | --- | --- | --- | --- | --- | --- | --- |
| 281 | 2.4.3.8 | **MP / Forfaitaire BAFO indienen** |  | 0d | 2023-06-27 | 2023-06-27 |  | 0d |  |  |  | Wk 26 |
| 282 | 2.4.3.8.1 | Idem MP / Indienen (wedstrijd-)dossier | milestone | 0d | 2023-06-27 | 2023-06-27 | 280 | 0d |  | Aannemer |  | Wk 26 |
| 283 | 2.4.3.8.2 | => Geoptimaliseerd ifv opmerkingen opdrachtgever | milestone | 0d | 2023-06-27 | 2023-06-27 | 280 | 0d |  | Aannemer |  | Wk 26 |
| 284 | 2.4.3.8.3 | Onderhandelingsmomenten | milestone | 0d | 2023-06-27 | 2023-06-27 | 280 | 0d |  | Aannemer |  | Wk 26 |
| 285 | 2.4.3.8.4 | Best ontvangen van BAFO-bestek | milestone | 0d | 2023-06-27 | 2023-06-27 | 280 | 0d |  | Aannemer |  | Wk 26 |
| 286 | 2.4.3.8.5 | Aanbeveling /Lijst met deliverables | milestone | 0d | 2023-06-27 | 2023-06-27 | 280 | 0d |  | DOC |  | Wk 26 |
| 287 | 2.5 | **FASE 5 / OMGEVINGSVERGUNNING & UITVOERINGSONTWERP** |  | 154d | 2023-06-28 | 2024-02-24 |  | 0d |  |  | 3624h | Wk 26 |
| 288 | 2.5.1 | **OMGEVINGSVERGUNNING** |  | 81d | 2023-06-28 | 2023-11-10 |  | 0d |  |  | 1272h | Wk 26 |
| 289 | 2.5.1.1 | Uitwerken definitief ontwerp |  | 10d | 2023-06-28 | 2023-07-11 | 281 | 0d |  | D&B-team | 80h | Wk 26 |
| 290 | 2.5.1.2 | **KICKOFF & ORGANISATIE BOUWTRAJECT** |  | 51d | 2023-07-12 | 2023-10-12 |  | 0d |  |  | 392h | Wk 28 |
| 291 | 2.5.1.2.1 | Kickoff |  | 1d | 2023-07-12 | 2023-07-12 | 289 | 0d |  | D&B-team | 8h | Wk 28 |
| 292 | 2.5.1.2.2 | Roadmap bouwtraject |  | 1d | 2023-07-12 | 2023-07-12 | 289 | 0d |  | D&B-team | 8h | Wk 28 |
| 293 | 2.5.1.2.3 | Opstellen BIM, Lean & Team afspraken |  | 1d | 2023-07-12 | 2023-07-12 | 289 | 0d |  | D&B-team | 8h | Wk 28 |
| 294 | 2.5.1.2.4 | **Wekelijkse Teammeeting** |  | 46d | 2023-08-09 | 2023-10-12 | 291SS+5d | 0d |  | D&B-team | 368h | Wk 32 |
| 295 | 2.5.1.2.4.1 | Wekelijkse Teammeeting 1 |  | 1d | 2023-08-09 | 2023-08-09 | 291SS+5d | 0d | start no earlier than 2023-01-02 |  |  | Wk 32 |
| 296 | 2.5.1.2.4.2 | Wekelijkse Teammeeting 2 |  | 1d | 2023-08-17 | 2023-08-17 | 295SS+5d | 0d | start no earlier than 2023-01-09 |  |  | Wk 33 |
| 297 | 2.5.1.2.4.3 | Wekelijkse Teammeeting 3 |  | 1d | 2023-08-24 | 2023-08-24 | 296SS+5d | 0d | start no earlier than 2023-01-16 |  |  | Wk 34 |
| 298 | 2.5.1.2.4.4 | Wekelijkse Teammeeting 4 |  | 1d | 2023-08-31 | 2023-08-31 | 297SS+5d | 0d | start no earlier than 2023-01-23 |  |  | Wk 35 |
| 299 | 2.5.1.2.4.5 | Wekelijkse Teammeeting 5 |  | 1d | 2023-09-07 | 2023-09-07 | 298SS+5d | 0d | start no earlier than 2023-01-30 |  |  | Wk 36 |
| 300 | 2.5.1.2.4.6 | Wekelijkse Teammeeting 6 |  | 1d | 2023-09-14 | 2023-09-14 | 299SS+5d | 0d | start no earlier than 2023-02-06 |  |  | Wk 37 |
| 301 | 2.5.1.2.4.7 | Wekelijkse Teammeeting 7 |  | 1d | 2023-09-21 | 2023-09-21 | 300SS+5d | 0d | start no earlier than 2023-02-13 |  |  | Wk 38 |
| 302 | 2.5.1.2.4.8 | Wekelijkse Teammeeting 8 |  | 1d | 2023-09-28 | 2023-09-28 | 301SS+5d | 0d | start no earlier than 2023-02-20 |  |  | Wk 39 |
| 303 | 2.5.1.2.4.9 | Wekelijkse Teammeeting 9 |  | 1d | 2023-10-05 | 2023-10-05 | 302SS+5d | 0d | start no earlier than 2023-02-20 |  |  | Wk 40 |
| 304 | 2.5.1.2.4.10 | Wekelijkse Teammeeting 10 |  | 1d | 2023-10-12 | 2023-10-12 | 303SS+5d | 0d | start no earlier than 2023-02-20 |  |  | Wk 41 |
| 305 | 2.5.1.3 | Start BIM-model (AA neemt de lead) |  | 20d | 2023-07-13 | 2023-08-31 | 291 | 0d |  | D&B-team | 160h | Wk 28 |
| 306 | 2.5.1.4 | Verkavelingsvergunning aanvragen |  | 5d | 2023-09-01 | 2023-09-07 | 305 | 0d |  | Bouwheer | 40h | Wk 35 |
| 307 | 2.5.1.5 | Adviesaanvraag monumenten & landschappen, brandweer, toegankelijkheid, bouwdienst, … |  | 5d | 2023-09-01 | 2023-09-07 | 305 | 0d |  | Architect | 40h | Wk 35 |
| 308 | 2.5.1.6 | Opmaken principieel bouwaanvraagdossier |  | 5d | 2023-09-01 | 2023-09-07 | 305 | 0d |  | Architect | 40h | Wk 35 |
| 309 | 2.5.1.7 | Opmaken administratief dossier |  | 5d | 2023-09-08 | 2023-09-14 | 308 | 0d |  | Architect | 40h | Wk 36 |
| 310 | 2.5.1.8 | Opmaken bemalingsnota |  | 10d | 2023-09-01 | 2023-09-14 | 305 | 0d |  | Aannemer | 80h | Wk 35 |
| 311 | 2.5.1.9 | Opmaken milieuvergunningsaanvraag / omgevingsvergunning |  | 5d | 2023-09-15 | 2023-09-21 | 310 | 0d |  | Bouwheer | 40h | Wk 37 |
| 312 | 2.5.1.10 | Opmaken dossier & aanvragen overige vergunningen |  | 5d | 2023-09-22 | 2023-09-28 | 311 | 0d |  | Bouwheer | 40h | Wk 38 |
| 313 | 2.5.1.11 | Opmaken milieueffectenrapport |  | 5d | 2023-09-29 | 2023-10-05 | 312 | 0d |  | Bouwheer | 40h | Wk 39 |
| 314 | 2.5.1.12 | Opmaken milieueffectenstudie |  | 5d | 2023-10-06 | 2023-10-12 | 313 | 0d |  | Bouwheer | 40h | Wk 40 |

| ID | WBS | Task | Type | Duration | Start | Finish | Predecessors | Total slack | Resources | Work | Weeknr |
| --- | --- | --- | --- | --- | --- | --- | --- | --- | --- | --- | --- |
| 315 | 2.5.1.13 | **MP / Indienen milieuvergunningsdossier / omgevingsvergunning** |  | 0d | 2023-10-12 | 2023-10-12 |  | 0d |  |  | Wk 41 |
| 316 | 2.5.1.13.1 | Stedenbouw | milestone | 0d | 2023-10-12 | 2023-10-12 | 314 | 0d | Bouwheer |  | Wk 41 |
| 317 | 2.5.1.13.2 | Inter | milestone | 0d | 2023-10-12 | 2023-10-12 | 314 | 0d | Bouwheer |  | Wk 41 |
| 318 | 2.5.1.13.3 | Brandweer | milestone | 0d | 2023-10-12 | 2023-10-12 | 314 | 0d | Bouwheer |  | Wk 41 |
| 319 | 2.5.1.13.4 | Inschatten risico bezwaarschriften OMV | milestone | 0d | 2023-10-12 | 2023-10-12 | 314 | 0d | Bouwheer |  | Wk 41 |
| 320 | 2.5.1.13.5 | MER/Milieuvergunning (IIOA) | milestone | 0d | 2023-10-12 | 2023-10-12 | 314 | 0d | Bouwheer |  | Wk 41 |
| 321 | 2.5.1.13.6 | Archeologienota | milestone | 0d | 2023-10-12 | 2023-10-12 | 314 | 0d | Bouwheer |  | Wk 41 |
| 322 | 2.5.1.13.7 | Bemalingsnota | milestone | 0d | 2023-10-12 | 2023-10-12 | 314 | 0d | Bouwheer |  | Wk 41 |
| 323 | 2.5.1.13.8 | SloopOpvolgingsPlan (SOP) | milestone | 0d | 2023-10-12 | 2023-10-12 | 314 | 0d | Bouwheer |  | Wk 41 |
| 324 | 2.5.1.13.9 | Verslag Grondverzet | milestone | 0d | 2023-10-12 | 2023-10-12 | 314 | 0d | Bouwheer |  | Wk 41 |
| 325 | 2.5.1.13.10 | Omgevingsplan | milestone | 0d | 2023-10-12 | 2023-10-12 | 314 | 0d | Bouwheer |  | Wk 41 |
| 326 | 2.5.1.13.11 | Contracten studiebureau's | milestone | 0d | 2023-10-12 | 2023-10-12 | 314 | 0d | Bouwheer |  | Wk 41 |
| 327 | 2.5.1.14 | Ondersteunen bij bijkomende verplichtingen ikv stedenbouwkundige vergunning |  | 10d | 2023-10-13 | 2023-10-26 | 315 | 0d | Architect | 80h | Wk 41 |
| 328 | 2.5.1.15 | Indienen van ev. beroep tegen de stedenbouwkundige vergunning |  | 5d | 2023-10-13 | 2023-10-19 | 314 | 0d | Bouwheer | 40h | Wk 41 |
| 329 | 2.5.1.16 | Ondersteunen bij eventueel beroep tegen de stedenbouwkundige vergunning |  | 5d | 2023-10-27 | 2023-11-03 | 327 | 0d | Architect | 40h | Wk 43 |
| 330 | 2.5.1.17 | Opmaken afwijkingsaanvraag brandveiligheid |  | 5d | 2023-10-20 | 2023-10-26 | 328 | 0d | Bouwheer | 40h | Wk 42 |
| 331 | 2.5.1.18 | Opmaken afbraakdossier Tracimat (Vlaanderen) |  | 5d | 2023-11-06 | 2023-11-10 | 329 | 0d | Architect | 40h | Wk 45 |
| 332 | 2.5.2 | BEOORDELING OMGEVINGSVERGUNNING |  | 135ed | 2023-10-12 | 2024-02-24 | 315 | 0d |  |  | Wk 41 |
| 333 | 2.5.3 | **UITVOERINGSONTWERP** |  | 93d | 2023-10-12 | 2024-02-24 |  | 0d |  | 2352h | Wk 41 |
| 334 | 2.5.3.1 | MP / Ontvangen milieuvergunning / omgevingsvergunning / bouwvergunning | milestone | 0d | 2024-02-24 | 2024-02-24 | 332 | 0d | Bouwheer |  | Wk 8 |
| 335 | 2.5.3.2 | **KICKOFF & ORGANISATIE BOUWTRAJECT** |  | 91d | 2023-10-12 | 2024-02-21 |  | 0d |  | 712h | Wk 41 |
| 336 | 2.5.3.2.1 | **MP / Kickoff Teammeeting** |  | 0d | 2023-10-12 | 2023-10-12 |  | 0d |  |  | Wk 41 |
| 337 | 2.5.3.2.1.1 | Voorzet planning Uitvoeringsontwerp-fase | milestone | 0d | 2023-10-12 | 2023-10-12 | 326 | 0d | Aannemer |  | Wk 41 |
| 338 | 2.5.3.2.1.2 | Voorzet BIM, Lean & Team afspraken | milestone | 0d | 2023-10-12 | 2023-10-12 | 326 | 0d | Aannemer |  | Wk 41 |
| 339 | 2.5.3.2.2 | Kickoff |  | 1d | 2023-10-13 | 2023-10-13 | 326 | 0d | D&B-team | 8h | Wk 41 |
| 340 | 2.5.3.2.3 | Roadmap bouwtraject |  | 1d | 2023-10-13 | 2023-10-13 | 326 | 0d | D&B-team | 8h | Wk 41 |
| 341 | 2.5.3.2.4 | Opstellen BIM, Lean & Team afspraken |  | 1d | 2023-10-13 | 2023-10-13 | 326 | 0d | D&B-team | 8h | Wk 41 |

| ID | WBS | Task | Type | Duration | Start | Finish | Predecessors | Total slack | Free slack | Constraint | Resources | Work | Weeknr |
| --- | --- | --- | --- | --- | --- | --- | --- | --- | --- | --- | --- | --- | --- |
| 342 | 2.5.3.2.5 | **Wekelijkse Teammeeting** |  | 86d | 2023-10-20 | 2024-02-21 | 339SS+5d | 0d |  |  | D&B-team | 688h | Wk 42 |
| 343 | 2.5.3.2.5.1 | Wekelijkse Teammeeting 1 |  | 1d | 2023-10-20 | 2023-10-20 | 339SS+5d | 0d |  | start no earlier than 2023-01-02 |  |  | Wk 42 |
| 344 | 2.5.3.2.5.2 | Wekelijkse Teammeeting 2 |  | 1d | 2023-10-27 | 2023-10-27 | 343SS+5d | 0d |  | start no earlier than 2023-01-09 |  |  | Wk 43 |
| 345 | 2.5.3.2.5.3 | Wekelijkse Teammeeting 3 |  | 1d | 2023-11-06 | 2023-11-06 | 344SS+5d | 0d |  | start no earlier than 2023-01-16 |  |  | Wk 45 |
| 346 | 2.5.3.2.5.4 | Wekelijkse Teammeeting 4 |  | 1d | 2023-11-13 | 2023-11-13 | 345SS+5d | 0d |  | start no earlier than 2023-01-23 |  |  | Wk 46 |
| 347 | 2.5.3.2.5.5 | Wekelijkse Teammeeting 5 |  | 1d | 2023-11-20 | 2023-11-20 | 346SS+5d | 0d |  | start no earlier than 2023-01-30 |  |  | Wk 47 |
| 348 | 2.5.3.2.5.6 | Wekelijkse Teammeeting 6 |  | 1d | 2023-11-27 | 2023-11-27 | 347SS+5d | 0d |  | start no earlier than 2023-02-06 |  |  | Wk 48 |
| 349 | 2.5.3.2.5.7 | Wekelijkse Teammeeting 7 |  | 1d | 2023-12-04 | 2023-12-04 | 348SS+5d | 0d |  | start no earlier than 2023-02-13 |  |  | Wk 49 |
| 350 | 2.5.3.2.5.8 | Wekelijkse Teammeeting 8 |  | 1d | 2023-12-11 | 2023-12-11 | 349SS+5d | 0d |  | start no earlier than 2023-02-20 |  |  | Wk 50 |
| 351 | 2.5.3.2.5.9 | Wekelijkse Teammeeting 9 |  | 1d | 2023-12-18 | 2023-12-18 | 350SS+5d | 0d |  | start no earlier than 2023-01-02 |  |  | Wk 51 |
| 352 | 2.5.3.2.5.10 | Wekelijkse Teammeeting 10 |  | 1d | 2023-12-26 | 2023-12-26 | 351SS+5d | 0d |  | start no earlier than 2023-01-09 |  |  | Wk 52 |
| 353 | 2.5.3.2.5.11 | Wekelijkse Teammeeting 11 |  | 1d | 2024-01-03 | 2024-01-03 | 352SS+5d | 0d |  | start no earlier than 2023-01-16 |  |  | Wk 1 |
| 354 | 2.5.3.2.5.12 | Wekelijkse Teammeeting 12 |  | 1d | 2024-01-10 | 2024-01-10 | 353SS+5d | 0d |  | start no earlier than 2023-01-23 |  |  | Wk 2 |
| 355 | 2.5.3.2.5.13 | Wekelijkse Teammeeting 13 |  | 1d | 2024-01-17 | 2024-01-17 | 354SS+5d | 0d |  | start no earlier than 2023-01-30 |  |  | Wk 3 |
| 356 | 2.5.3.2.5.14 | Wekelijkse Teammeeting 14 |  | 1d | 2024-01-24 | 2024-01-24 | 355SS+5d | 0d |  | start no earlier than 2023-02-06 |  |  | Wk 4 |
| 357 | 2.5.3.2.5.15 | Wekelijkse Teammeeting 15 |  | 1d | 2024-01-31 | 2024-01-31 | 356SS+5d | 0d |  | start no earlier than 2023-02-13 |  |  | Wk 5 |
| 358 | 2.5.3.2.5.16 | Wekelijkse Teammeeting 16 |  | 1d | 2024-02-07 | 2024-02-07 | 357SS+5d | 0d |  | start no earlier than 2023-02-20 |  |  | Wk 6 |
| 359 | 2.5.3.2.5.17 | Wekelijkse Teammeeting 17 |  | 1d | 2024-02-14 | 2024-02-14 | 358SS+5d | 0d |  | start no earlier than 2023-02-20 |  |  | Wk 7 |
| 360 | 2.5.3.2.5.18 | Wekelijkse Teammeeting 18 |  | 1d | 2024-02-21 | 2024-02-21 | 359SS+5d | 0d |  | start no earlier than 2023-02-20 |  |  | Wk 8 |
| 361 | 2.5.3.3 | Actualisatie definitief ontwerp |  | 10d | 2023-10-16 | 2023-10-27 | 339 | 0d |  |  | D&B-team | 80h | Wk 42 |
| 362 | 2.5.3.4 | Goedkeuren van het uitvoeringsontwerp project => DESIGN FREEZE | milestone | 0d | 2023-10-27 | 2023-10-27 | 361 | 0d |  |  | Bouwheer |  | Wk 43 |
| 363 | 2.5.3.5 | Aanvangsbevel | milestone | 0d | 2023-10-27 | 2023-10-27 | 362 | 0d |  |  | Bouwheer |  | Wk 43 |
| 364 | 2.5.3.6 | Samenstellen werfteam |  | 5d | 2023-10-30 | 2023-11-06 | 362 | 7d | 0d |  | Aannemer | 40h | Wk 44 |
| 365 | 2.5.3.7 | Opstellen masterplanning: aankoop - opstart - uitvoering - … |  | 5d | 2023-11-07 | 2023-11-13 | 364 | 7d | 0d |  | Aannemer | 40h | Wk 45 |
| 366 | 2.5.3.8 | Werkvoorbereiding - Voorbereiden prefab elementen |  | 5d | 2023-11-14 | 2023-11-20 | 365 | 7d | 0d |  | Aannemer | 40h | Wk 46 |
| 367 | 2.5.3.9 | Werkvoorbereiding - Uitwerken detailplannen |  | 5d | 2023-11-21 | 2023-11-27 | 366 | 7d | 0d |  | Aannemer | 40h | Wk 47 |
| 368 | 2.5.3.10 | Werkvoorbereiding - Opstellen meetstaat (focus ruwbouw) |  | 5d | 2023-11-28 | 2023-12-04 | 367 | 7d | 0d |  | Aannemer | 40h | Wk 48 |
| 369 | 2.5.3.11 | Werkvoorbereiding - Indienen offerte-aanvragen (focus ruwbouw) |  | 5d | 2023-12-05 | 2023-12-11 | 368 | 7d | 0d |  | Aannemer | 40h | Wk 49 |
| 370 | 2.5.3.12 | Werkvoorbereiding - Ontvangen offertes (focus ruwbouw) |  | 10d | 2023-12-12 | 2023-12-26 | 369 | 7d | 0d |  | Aannemer | 80h | Wk 50 |
| 371 | 2.5.3.13 | Werkvoorbereiding - Prijsvergelijken (focus ruwbouw) |  | 5d | 2023-12-27 | 2024-01-03 | 370 | 7d | 0d |  | Aannemer | 40h | Wk 52 |
| 372 | 2.5.3.14 | Werkvoorbereiding - Selecteren OA's (focus ruwbouw) |  | 5d | 2024-01-04 | 2024-01-10 | 371 | 7d | 0d |  | Aannemer | 40h | Wk 1 |
| 373 | 2.5.3.15 | Werkvoorbereiding - Plaatsen bestellingen (focus ruwbouw) |  | 5d | 2024-01-11 | 2024-01-17 | 372 | 7d | 0d |  | Aannemer | 40h | Wk 2 |
| 374 | 2.5.3.16 | Werforganisatie - Opstellen werfinrichting & werfinrichtingsplan |  | 5d | 2024-01-18 | 2024-01-24 | 373 | 7d | 0d |  | Aannemer | 40h | Wk 3 |
| 375 | 2.5.3.17 | Werforganisatie - Aanschrijven instanties (nutsleidingen, werfaansluitingen, vergunningen, verzekeringen) |  | 5d | 2024-01-25 | 2024-01-31 | 374 | 7d | 0d |  | Aannemer | 40h | Wk 4 |
| 376 | 2.5.3.18 | Werfspecifieke voorbereiding |  | 5d | 2024-02-01 | 2024-02-07 | 375 | 7d | 0d |  | Aannemer | 40h | Wk 5 |
| 377 | 2.5.3.19 | Uitwerken ontwerp bouwwerken en inrichting architectuur |  | 10d | 2023-10-30 | 2023-11-13 | 363 | 0d |  |  | Architect | 80h | Wk 44 |
| 378 | 2.5.3.20 | Uitwerken ontwerp bouwwerken en inrichting: detaillering architectuur |  | 5d | 2023-11-14 | 2023-11-20 | 377 | 0d |  |  | Architect | 40h | Wk 46 |
| 379 | 2.5.3.21 | Opstellen technische specificaties / bestek architectuur |  | 5d | 2023-11-21 | 2023-11-27 | 378 | 0d |  |  | Architect | 40h | Wk 47 |
| 380 | 2.5.3.22 | Aftoetsen technisch ontwerp aan PvE en regelgeving |  | 5d | 2023-11-28 | 2023-12-04 | 379 | 0d |  |  | Architect | 40h | Wk 48 |
| 381 | 2.5.3.23 | Aftoetsen technisch ontwerp buitenaanleg aan PvE en regelgeving |  | 5d | 2023-12-05 | 2023-12-11 | 380 | 0d |  |  | Architect | 40h | Wk 49 |
| 382 | 2.5.3.24 | Opmaken definitief ontwerp technieken |  | 5d | 2023-10-30 | 2023-11-06 | 363 | 0d |  |  | Studiebureau Technieken | 40h | Wk 44 |
| 383 | 2.5.3.25 | Uitwerken dimensionering van installaties |  | 5d | 2023-11-07 | 2023-11-13 | 382 | 0d |  |  | Studiebureau Technieken | 40h | Wk 45 |
| 384 | 2.5.3.26 | Opmaken van een grafisch dossier |  | 5d | 2023-11-14 | 2023-11-20 | 383 | 0d |  |  | Studiebureau Technieken | 40h | Wk 46 |
| 385 | 2.5.3.27 | Opstellen technische specificaties / bestek |  | 5d | 2023-11-21 | 2023-11-27 | 384 | 0d |  |  | Studiebureau Technieken | 40h | Wk 47 |
| 386 | 2.5.3.28 | Opstellen meetstaat |  | 5d | 2023-11-28 | 2023-12-04 | 385 | 0d |  |  | Studiebureau Technieken | 40h | Wk 48 |
| 387 | 2.5.3.29 | Aftoetsen technisch ontwerp aan PvE en regelgeving |  | 5d | 2023-12-05 | 2023-12-11 | 386 | 0d |  |  | Studiebureau Technieken | 40h | Wk 49 |
| 388 | 2.5.3.30 | Opmaken technisch ontwerp stabiliteit |  | 4d | 2023-10-30 | 2023-11-03 | 363 | 0d |  |  | Studiebureau Stabiliteit | 32h | Wk 44 |
| 389 | 2.5.3.31 | Selectie tussen prefabricatie / ter plekke te storten |  | 1d | 2023-11-06 | 2023-11-06 | 388 | 0d |  |  | Studiebureau Stabiliteit | 8h | Wk 45 |
| 390 | 2.5.3.32 | Opmaken ontwerp fundering / bouwput |  | 5d | 2023-11-07 | 2023-11-13 | 389 | 0d |  |  | Studiebureau Stabiliteit | 40h | Wk 45 |
| 391 | 2.5.3.33 | Opmaken ontwerp structuren, vloerplaten en muren (beton & staal) |  | 5d | 2023-11-14 | 2023-11-20 | 390 | 0d |  |  | Studiebureau Stabiliteit | 40h | Wk 46 |
| 392 | 2.5.3.34 | Opmaken detaillering van de prefab elementen in beton en meetstaat |  | 2d | 2023-11-21 | 2023-11-22 | 391 | 0d |  |  | Studiebureau Stabiliteit | 16h | Wk 47 |
| 393 | 2.5.3.35 | Opmaken van detaillering elementen in ter plaatse gestort beton en meetstaat |  | 3d | 2023-11-23 | 2023-11-27 | 392 | 0d |  |  | Studiebureau Stabiliteit | 24h | Wk 47 |
| 394 | 2.5.3.36 | Opmaken van detaillering staalstructuur en meetstaat |  | 5d | 2023-11-28 | 2023-12-04 | 393 | 0d |  |  | Studiebureau Stabiliteit | 40h | Wk 48 |
| 395 | 2.5.3.37 | Opstellen technische specificaties/ bestek/meetstaat |  | 5d | 2023-12-05 | 2023-12-11 | 394 | 0d |  |  | Studiebureau Stabiliteit | 40h | Wk 49 |
| 396 | 2.5.3.38 | Opmaken getekend aangifteformulier van de EPB aangifte |  | 5d | 2023-10-30 | 2023-11-06 | 363 | 0d |  |  | Studiebureau's - Overig | 40h | Wk 44 |
| 397 | 2.5.3.39 | Simuleren resultaat van de duurzaamheid vanuit het schetsontwerp |  | 5d | 2023-11-07 | 2023-11-13 | 396 | 0d |  |  | Studiebureau's - Overig | 40h | Wk 45 |
| 398 | 2.5.3.40 | Opmaken ventilatierapport |  | 5d | 2023-11-14 | 2023-11-20 | 397 | 0d |  |  | Studiebureau's - Overig | 40h | Wk 46 |
| 399 | 2.5.3.41 | Aftoetsen wettelijke vereisten EPB |  | 5d | 2023-11-21 | 2023-11-27 | 398 | 0d |  |  | Studiebureau's - Overig | 40h | Wk 47 |
| 400 | 2.5.3.42 | Aftoetsen duurzaamheidscertificatie |  | 5d | 2023-11-28 | 2023-12-04 | 399 | 0d |  |  | Studiebureau's - Overig | 40h | Wk 48 |
| 401 | 2.5.3.43 | Veiligheid ontwerp |  | 3d | 2023-12-05 | 2023-12-07 | 400 | 0d |  |  | Studiebureau's - Overig | 24h | Wk 49 |
| 402 | 2.5.3.44 | Veiligheid uitvoering |  | 2d | 2023-12-08 | 2023-12-11 | 401 | 0d |  |  | Studiebureau's - Overig | 16h | Wk 49 |
| 403 | 2.5.3.45 | Budget bewaken |  | 5d | 2024-02-08 | 2024-02-14 | 376 | 7d |  |  | D&B-team | 40h | Wk 6 |

| ID | WBS | Task | Type | Duration | Start | Finish | Predecessors | Total slack | Deadline | Resources | Weeknr |
| --- | --- | --- | --- | --- | --- | --- | --- | --- | --- | --- | --- |
| 404 | 2.6 | **SCHOP IN DE GROND** |  | 0d | 2024-02-24 | 2024-02-24 |  | 0d | 2024-02-26 |  | Wk 8 |
| 405 | 2.6.1 | Wie is verantwoordelijk voor uitvoeringsdossier tijdens behandelingstermijn omgevingsvergunning | milestone | 0d | 2024-02-24 | 2024-02-24 | 403, 332 | 0d |  | D&B-team | Wk 8 |
| 406 | 2.6.2 | Bekistingsplannen | milestone | 0d | 2024-02-24 | 2024-02-24 | 403, 332 | 0d |  | D&B-team | Wk 8 |
| 407 | 2.6.3 | Wapeningsplannen/buigstaten | milestone | 0d | 2024-02-24 | 2024-02-24 | 403, 332 | 0d |  | D&B-team | Wk 8 |
| 408 | 2.6.4 | Definitieve architectuurplannen/-snedes/-gevels | milestone | 0d | 2024-02-24 | 2024-02-24 | 403, 332 | 0d |  | D&B-team | Wk 8 |
| 409 | 2.6.5 | Details | milestone | 0d | 2024-02-24 | 2024-02-24 | 403, 332 | 0d |  | D&B-team | Wk 8 |
| 410 | 2.6.6 | Uitvoeringsplannen Technieken | milestone | 0d | 2024-02-24 | 2024-02-24 | 403, 332 | 0d |  | D&B-team | Wk 8 |
| 411 | 2.6.7 | Compartimenteringsplannen | milestone | 0d | 2024-02-24 | 2024-02-24 | 403, 332 | 0d |  | D&B-team | Wk 8 |
| 412 | 2.6.8 | Borderel ramen/deuren | milestone | 0d | 2024-02-24 | 2024-02-24 | 403, 332 | 0d |  | D&B-team | Wk 8 |
| 413 | 2.6.9 | Omgevingsplan | milestone | 0d | 2024-02-24 | 2024-02-24 | 403, 332 | 0d |  | D&B-team | Wk 8 |
| 414 | 2.6.10 | Vereiste ISO14001 mbt milieu, … | milestone | 0d | 2024-02-24 | 2024-02-24 | 403, 332 | 0d |  |  | Wk 8 |
| 415 | 2.6.11 | Melding asbestverwijdering | milestone | 0d | 2024-02-24 | 2024-02-24 | 403, 332 | 0d |  | D&B-team | Wk 8 |
| 416 | 2.6.12 | Tracimat | milestone | 0d | 2024-02-24 | 2024-02-24 | 403, 332 | 0d |  | D&B-team | Wk 8 |
| 417 | 2.6.13 | Contracten OA's | milestone | 0d | 2024-02-24 | 2024-02-24 | 403, 332 | 0d |  | D&B-team | Wk 8 |
| 418 | 2.6.14 | EPB-aangifte startverklaring | milestone | 0d | 2024-02-24 | 2024-02-24 | 403, 332 | 0d |  | D&B-team | Wk 8 |
| 419 | 2.6.15 | GRO-finaal | milestone | 0d | 2024-02-24 | 2024-02-24 | 403, 332 | 0d |  | D&B-team | Wk 8 |
